# Myth 3 Project

Schedule from MS Project, 2000-11-15 to 2001-10-18.
Ritual Entertainment

## Calendars

- Standard: Mon-Fri 08:00-12:00, 13:00-17:00; Sat-Sun off. Exceptions (off unless hours are given): 2001-09-01 08:00-12:00, 13:00-17:00.

## Resources

| Resource | Group |
| --- | --- |
| Project Manager |  |
| Lead Programmer | Programming |
| Assistant Programmer | Programming |
| Senior Artist | Artist |
| Modeler/Animator 1 | Artist |
| Modeler/Animator 2 | Artist |
| Texturer 1 | Artist |
| Texturer 2 | Artist |
| Assistant Artist | Artist |
| Level Builder 1 | Design |
| Level Builder 2 | Design |
| Lead Level Builder | Design |
| Sketch Artist 1 | Out-of-House |
| Sketch Artist 2 | Out-of-House |
| Sketch Artist 3 | Out-of-House |
| Out-of-House Music | Out-of-House |
| Out-of-House Sound FX | Out-of-House |
| Out-of-House Narration | Out-of-House |

## Schedule

| ID | WBS | Task | Type | Duration | Start | Finish | Predecessors | Total slack | Free slack | Constraint | Deadline | Resources | Work |
| --- | --- | --- | --- | --- | --- | --- | --- | --- | --- | --- | --- | --- | --- |
| 1 | 1 | Code Production Starts | milestone | 0d | 2000-11-15 | 2000-11-15 |  | 3d |  | start no earlier than 2000-11-15 | 2000-11-17 |  |  |
| 2 | 2 | Milestone 3 | milestone | 0d | 2000-12-15 | 2000-12-15 |  | 217d |  | start no earlier than 2000-12-15 |  |  |  |
| 3 | 3 | Milestone 4 | milestone | 0d | 2001-02-01 | 2001-02-01 |  | 183d |  | start no earlier than 2001-02-01 |  |  |  |
| 4 | 4 | Milestone 5 | milestone | 0d | 2001-05-01 | 2001-05-01 |  | 120d |  | start no earlier than 2001-05-01 |  |  |  |
| 5 | 5 | Milestone 6 | milestone | 0d | 2001-08-01 | 2001-08-01 |  | 54d |  | start no earlier than 2001-08-01 |  |  |  |
| 6 | 6 | Milestone 7 | milestone | 0d | 2001-08-31 | 2001-08-31 |  | 32d |  | start no earlier than 2001-08-31 |  |  |  |
| 7 | 7 | Milestone 8 | milestone | 0d | 2001-10-01 | 2001-10-01 |  | 10d |  | start no earlier than 2001-10-01 |  |  |  |
| 8 | 8 | Milestone 9 | milestone | 0d | 2001-10-15 | 2001-10-15 |  | 4d |  | start no earlier than 2001-10-15 |  |  |  |
| 9 | 9 | **CODE ASSETS** |  | 243d? | 2000-11-15 | 2001-10-18 |  | 0d |  |  |  |  | 3792h |
| 10 | 9.1 | **LEAD PROGRAMMER** |  | 243d? | 2000-11-15 | 2001-10-18 |  | 0d |  |  |  |  | 1896h |
| 11 | 9.1.1 | Compile Myth 2 Code |  | 1w | 2000-11-15 | 2000-11-21 |  | 6d | 0d | start no earlier than 2000-11-15 |  | Lead Programmer | 40h |
| 12 | 9.1.2 | Open GL Renderer |  | 17d? | 2000-11-22 | 2000-12-14 | 11 | 6d | 0d | finish no earlier than 2000-12-14 |  | Lead Programmer | 136h |
| 13 | 9.1.3 | Standalone TIKI Playback |  | 1w | 2000-12-15 | 2000-12-21 | 12 | 6d |  | start no earlier than 2000-12-15 |  | Lead Programmer | 40h |
| 14 | 9.1.4 | TIKI Playback in-engine |  | 2w | 2001-01-01 | 2001-01-12 | 13 | 0d |  | start no earlier than 2001-01-01 |  | Lead Programmer | 80h |
| 15 | 9.1.5 | TIKI Models in Data Files |  | 2w | 2001-01-15 | 2001-01-26 | 14 | 0d |  | start no earlier than 2001-01-05 |  | Lead Programmer | 80h |
| 16 | 9.1.6 | TIKI Linked to AI / Scripting |  | 2w | 2001-01-29 | 2001-02-09 | 15 | 0d |  | start no earlier than 2001-01-19 |  | Lead Programmer | 80h |
| 17 | 9.1.7 | Colored Lighting and Shadows |  | 4w | 2001-02-12 | 2001-03-09 | 16 | 0d |  | start no earlier than 2001-02-02 |  | Lead Programmer | 160h |
| 18 | 9.1.8 | Trees and Bushes |  | 4w | 2001-03-12 | 2001-04-06 | 17 | 0d |  |  |  | Lead Programmer | 160h |
| 19 | 9.1.9 | Grass Effects |  | 1w | 2001-04-09 | 2001-04-13 | 18 | 0d |  | start no earlier than 2001-03-25 |  | Lead Programmer | 40h |
| 20 | 9.1.10 | AI / Scripting Additions |  | 6w | 2001-04-16 | 2001-05-25 | 19 | 0d |  |  |  | Lead Programmer | 240h |
| 21 | 9.1.11 | Special Effects |  | 6w | 2001-05-28 | 2001-07-06 | 20 | 0d |  |  |  | Lead Programmer | 240h |
| 22 | 9.1.12 | Localization |  | 4w | 2001-07-09 | 2001-08-03 | 21 | 0d |  |  |  | Lead Programmer | 160h |
| 23 | 9.1.13 | Pre-Release Demo |  | 3w | 2001-08-06 | 2001-08-24 | 22 | 0d |  |  |  | Lead Programmer | 120h |
| 24 | 9.1.14 | Bug Fixes |  | 8w | 2001-08-27 | 2001-10-18 | 23 | 0d |  |  |  | Lead Programmer | 320h |

| ID | WBS | Task | Duration | Start | Finish | Predecessors | Total slack | Free slack | Constraint | Resources | Work |
| --- | --- | --- | --- | --- | --- | --- | --- | --- | --- | --- | --- |
| 25 | 9.2 | **ASSISTANT PROGRAMMER** | 243d? | 2000-11-15 | 2001-10-18 |  | 0d |  |  |  | 1896h |
| 26 | 9.2.1 | Compile Myth 2 Code | 1w | 2000-11-15 | 2000-11-21 |  | 0d |  | start no earlier than 2000-11-15 | Assistant Programmer | 40h |
| 27 | 9.2.2 | Fix Mouse Bug for Win2K | 3d | 2000-11-22 | 2000-11-24 | 26 | 0d |  |  | Assistant Programmer | 24h |
| 28 | 9.2.3 | Open GL Renderer | 14d? | 2000-11-27 | 2000-12-14 | 27 | 0d |  | finish no earlier than 2000-12-14 | Assistant Programmer | 112h |
| 29 | 9.2.4 | Terrain Multi-Texturing | 4w | 2000-12-15 | 2001-01-19 | 28 | 0d |  |  | Assistant Programmer | 160h |
| 30 | 9.2.5 | Terrain Editing / Import | 3w | 2001-01-22 | 2001-02-09 | 29 | 0d |  |  | Assistant Programmer | 120h |
| 31 | 9.2.6 | Colored Lighting and Shadows | 4w | 2001-02-12 | 2001-03-09 | 30 | 0d |  | start no earlier than 2001-02-02 | Assistant Programmer | 160h |
| 32 | 9.2.7 | Scriptable Camera Movement | 2w | 2001-03-12 | 2001-03-23 | 31 | 0d |  |  | Assistant Programmer | 80h |
| 33 | 9.2.8 | Water Effects | 3w | 2001-03-26 | 2001-04-13 | 32 | 0d |  | start no earlier than 2001-03-11 | Assistant Programmer | 120h |
| 34 | 9.2.9 | AI / Scripting Additions | 6w | 2001-04-16 | 2001-05-25 | 33 | 0d |  |  | Assistant Programmer | 240h |
| 35 | 9.2.10 | Interface | 6w | 2001-05-28 | 2001-07-06 | 34 | 0d |  |  | Assistant Programmer | 240h |
| 36 | 9.2.11 | Localization | 4w | 2001-07-09 | 2001-08-03 | 35 | 0d |  |  | Assistant Programmer | 160h |
| 37 | 9.2.12 | Pre-Release Demo | 3w | 2001-08-06 | 2001-08-24 | 36 | 0d |  |  | Assistant Programmer | 120h |
| 38 | 9.2.13 | Bug Fixes | 8w | 2001-08-27 | 2001-10-18 | 37 | 0d |  |  | Assistant Programmer | 320h |
| 39 | 10 | **DESIGN ASSETS** | 220d? | 2000-11-27 | 2001-09-27 |  | 15d |  |  |  | 1680h |
| 40 | 10.1 | Myth 3 Teaser Movie | 15d? | 2000-11-27 | 2000-12-15 |  | 220d |  | start no earlier than 2000-11-27 | Project Manager | 120h |
| 41 | 10.2 | Unit Naming Conventions | 2w | 2001-01-01 | 2001-01-12 |  | 15d | 0d |  | Project Manager | 80h |
| 42 | 10.3 | **DIALOG WRITING** | 60d | 2001-01-15 | 2001-04-06 | 41 | 15d | 0d |  |  | 480h |
| 43 | 10.3.1 | Dialog Writing (Level 1) | 2d | 2001-01-15 | 2001-01-16 |  | 15d | 0d |  | Project Manager | 16h |
| 44 | 10.3.2 | Dialog Writing (Level 2) | 2d | 2001-01-17 | 2001-01-18 | 43 | 15d | 0d |  | Project Manager | 16h |
| 45 | 10.3.3 | Dialog Writing (Level 3) | 2d | 2001-01-19 | 2001-01-22 | 44 | 15d | 0d |  | Project Manager | 16h |
| 46 | 10.3.4 | Dialog Writing (Level 4) | 2d | 2001-01-23 | 2001-01-24 | 45 | 15d | 0d |  | Project Manager | 16h |
| 47 | 10.3.5 | Dialog Writing (Level 5) | 2d | 2001-01-25 | 2001-01-26 | 46 | 15d | 0d |  | Project Manager | 16h |
| 48 | 10.3.6 | Dialog Writing (Level 6) | 2d | 2001-01-29 | 2001-01-30 | 47 | 15d | 0d |  | Project Manager | 16h |
| 49 | 10.3.7 | Dialog Writing (Level 7) | 2d | 2001-01-31 | 2001-02-01 | 48 | 15d | 0d |  | Project Manager | 16h |
| 50 | 10.3.8 | Dialog Writing (Level 8) | 2d | 2001-02-02 | 2001-02-05 | 49 | 15d | 0d |  | Project Manager | 16h |
| 51 | 10.3.9 | Dialog Writing (Level 9) | 2d | 2001-02-06 | 2001-02-07 | 50 | 15d | 0d |  | Project Manager | 16h |
| 52 | 10.3.10 | Dialog Writing (Level 10) | 2d | 2001-02-08 | 2001-02-09 | 51 | 15d | 0d |  | Project Manager | 16h |
| 53 | 10.3.11 | Dialog Writing (Level 11) | 2d | 2001-02-12 | 2001-02-13 | 52 | 15d | 0d |  | Project Manager | 16h |
| 54 | 10.3.12 | Dialog Writing (Level 12) | 2d | 2001-02-14 | 2001-02-15 | 53 | 15d | 0d |  | Project Manager | 16h |
| 55 | 10.3.13 | Dialog Writing (Level 13) | 2d | 2001-02-16 | 2001-02-19 | 54 | 15d | 0d |  | Project Manager | 16h |
| 56 | 10.3.14 | Dialog Writing (Level 14) | 2d | 2001-02-20 | 2001-02-21 | 55 | 15d | 0d |  | Project Manager | 16h |
| 57 | 10.3.15 | Dialog Writing (Level 15) | 2d | 2001-02-22 | 2001-02-23 | 56 | 15d | 0d |  | Project Manager | 16h |
| 58 | 10.3.16 | Dialog Writing (Level 16) | 2d | 2001-02-26 | 2001-02-27 | 57 | 15d | 0d |  | Project Manager | 16h |
| 59 | 10.3.17 | Dialog Writing (Level 17) | 2d | 2001-02-28 | 2001-03-01 | 58 | 15d | 0d |  | Project Manager | 16h |
| 60 | 10.3.18 | Dialog Writing (Level 18) | 2d | 2001-03-02 | 2001-03-05 | 59 | 15d | 0d |  | Project Manager | 16h |
| 61 | 10.3.19 | Dialog Writing (Level 19) | 2d | 2001-03-06 | 2001-03-07 | 60 | 15d | 0d |  | Project Manager | 16h |
| 62 | 10.3.20 | Dialog Writing (Level 20) | 2d | 2001-03-08 | 2001-03-09 | 61 | 15d | 0d |  | Project Manager | 16h |
| 63 | 10.3.21 | Dialog Writing (Level 21) | 2d | 2001-03-12 | 2001-03-13 | 62 | 15d | 0d |  | Project Manager | 16h |
| 64 | 10.3.22 | Dialog Writing (Level 22) | 2d | 2001-03-14 | 2001-03-15 | 63 | 15d | 0d |  | Project Manager | 16h |
| 65 | 10.3.23 | Dialog Writing (Level 23) | 2d | 2001-03-16 | 2001-03-19 | 64 | 15d | 0d |  | Project Manager | 16h |
| 66 | 10.3.24 | Dialog Writing (Level 24) | 2d | 2001-03-20 | 2001-03-21 | 65 | 15d | 0d |  | Project Manager | 16h |
| 67 | 10.3.25 | Dialog Writing (Level 25) | 2d | 2001-03-22 | 2001-03-23 | 66 | 15d | 0d |  | Project Manager | 16h |
| 68 | 10.3.26 | Dialog Writing (Cut Scene 1) | 2d | 2001-03-26 | 2001-03-27 | 67 | 15d | 0d |  | Project Manager | 16h |
| 69 | 10.3.27 | Dialog Writing (Cut Scene 2) | 2d | 2001-03-28 | 2001-03-29 | 68 | 15d | 0d |  | Project Manager | 16h |
| 70 | 10.3.28 | Dialog Writing (Cut Scene 3) | 2d | 2001-03-30 | 2001-04-02 | 69 | 15d | 0d |  | Project Manager | 16h |
| 71 | 10.3.29 | Dialog Writing (Cut Scene 4) | 2d | 2001-04-03 | 2001-04-04 | 70 | 15d | 0d |  | Project Manager | 16h |
| 72 | 10.3.30 | Dialog Writing (Cut Scene 5) | 2d | 2001-04-05 | 2001-04-06 | 71 | 15d |  |  | Project Manager | 16h |
| 73 | 10.4 | Localization Management | 10w | 2001-04-09 | 2001-06-15 | 42 | 15d | 0d |  | Project Manager | 400h |
| 74 | 10.5 | Miscellaneous | 15w | 2001-06-18 | 2001-09-27 | 73 | 15d |  |  | Project Manager | 600h |

| ID | WBS | Task | Duration | Start | Finish | Predecessors | Total slack | Free slack | Resources | Work |
| --- | --- | --- | --- | --- | --- | --- | --- | --- | --- | --- |
| 75 | 11 | **LEVEL ASSETS** | 196d | 2001-01-01 | 2001-09-28 |  | 14d |  |  | 4680h |
| 76 | 11.1 | **LEAD DESIGNER** | 196d | 2001-01-01 | 2001-09-28 |  | 14d |  |  | 1544h |
| 77 | 11.1.1 | **Map (19-The Children of Bahl'al)** | 12d | 2001-01-01 | 2001-01-16 |  | 17d | 0d |  | 96h |
| 78 | 11.1.1.1 | Sketch Design | 2d | 2001-01-01 | 2001-01-02 |  | 17d | 0d | Lead Level Builder | 16h |
| 79 | 11.1.1.2 | Build Map / Place Scenery | 5d | 2001-01-03 | 2001-01-09 | 78 | 17d | 0d | Lead Level Builder | 40h |
| 80 | 11.1.1.3 | Place / Script Units | 5d | 2001-01-10 | 2001-01-16 | 79 | 17d |  | Lead Level Builder | 40h |
| 81 | 11.1.2 | **Map (Netplay-Catacombs)** | 12d | 2001-01-17 | 2001-02-01 | 77 | 17d | 0d |  | 96h |
| 82 | 11.1.2.1 | Sketch Design | 2d | 2001-01-17 | 2001-01-18 |  | 17d | 0d | Lead Level Builder | 16h |
| 83 | 11.1.2.2 | Build Map / Place Scenery | 5d | 2001-01-19 | 2001-01-25 | 82 | 17d | 0d | Lead Level Builder | 40h |
| 84 | 11.1.2.3 | Place / Script Units | 5d | 2001-01-26 | 2001-02-01 | 83 | 17d |  | Lead Level Builder | 40h |
| 85 | 11.1.3 | **Map (16-Refugees)** | 12d | 2001-02-02 | 2001-02-19 | 81 | 17d | 0d |  | 96h |
| 86 | 11.1.3.1 | Sketch Design | 2d | 2001-02-02 | 2001-02-05 |  | 17d | 0d | Lead Level Builder | 16h |
| 87 | 11.1.3.2 | Build Map / Place Scenery | 5d | 2001-02-06 | 2001-02-12 | 86 | 17d | 0d | Lead Level Builder | 40h |
| 88 | 11.1.3.3 | Place / Script Units | 5d | 2001-02-13 | 2001-02-19 | 87 | 17d |  | Lead Level Builder | 40h |
| 89 | 11.1.4 | **Map (Netplay-Desert)** | 12d | 2001-02-20 | 2001-03-07 | 85 | 17d | 0d |  | 96h |
| 90 | 11.1.4.1 | Sketch Design | 2d | 2001-02-20 | 2001-02-21 |  | 17d | 0d | Lead Level Builder | 16h |
| 91 | 11.1.4.2 | Build Map / Place Scenery | 5d | 2001-02-22 | 2001-02-28 | 90 | 17d | 0d | Lead Level Builder | 40h |
| 92 | 11.1.4.3 | Place / Script Units | 5d | 2001-03-01 | 2001-03-07 | 91 | 17d |  | Lead Level Builder | 40h |
| 93 | 11.1.5 | **Map (Netplay-Jungle)** | 12d | 2001-03-08 | 2001-03-23 | 89 | 17d | 0d |  | 96h |
| 94 | 11.1.5.1 | Sketch Design | 2d | 2001-03-08 | 2001-03-09 |  | 17d | 0d | Lead Level Builder | 16h |
| 95 | 11.1.5.2 | Build Map / Place Scenery | 5d | 2001-03-12 | 2001-03-16 | 94 | 17d | 0d | Lead Level Builder | 40h |
| 96 | 11.1.5.3 | Place / Script Units | 5d | 2001-03-19 | 2001-03-23 | 95 | 17d |  | Lead Level Builder | 40h |
| 97 | 11.1.6 | **Map (15-Rebellion)** | 12d | 2001-03-26 | 2001-04-10 | 93 | 17d | 0d |  | 96h |
| 98 | 11.1.6.1 | Sketch Design | 2d | 2001-03-26 | 2001-03-27 |  | 17d | 0d | Lead Level Builder | 16h |
| 99 | 11.1.6.2 | Build Map / Place Scenery | 5d | 2001-03-28 | 2001-04-03 | 98 | 17d | 0d | Lead Level Builder | 40h |
| 100 | 11.1.6.3 | Place / Script Units | 5d | 2001-04-04 | 2001-04-10 | 99 | 17d |  | Lead Level Builder | 40h |

| ID | WBS | Task | Duration | Start | Finish | Predecessors | Total slack | Free slack | Constraint | Resources | Work |
| --- | --- | --- | --- | --- | --- | --- | --- | --- | --- | --- | --- |
| 101 | 11.1.7 | **Map (Netplay-Volcano)** | 12d | 2001-04-11 | 2001-04-26 | 97 | 17d | 0d |  |  | 96h |
| 102 | 11.1.7.1 | Sketch Design | 2d | 2001-04-11 | 2001-04-12 |  | 17d | 0d |  | Lead Level Builder | 16h |
| 103 | 11.1.7.2 | Build Map / Place Scenery | 5d | 2001-04-13 | 2001-04-19 | 102 | 17d | 0d |  | Lead Level Builder | 40h |
| 104 | 11.1.7.3 | Place / Script Units | 5d | 2001-04-20 | 2001-04-26 | 103 | 17d |  |  | Lead Level Builder | 40h |
| 105 | 11.1.8 | **Map (Netplay-Fortress)** | 12d | 2001-04-27 | 2001-05-14 | 101 | 17d | 0d |  |  | 96h |
| 106 | 11.1.8.1 | Sketch Design | 2d | 2001-04-27 | 2001-04-30 |  | 17d | 0d |  | Lead Level Builder | 16h |
| 107 | 11.1.8.2 | Build Map / Place Scenery | 5d | 2001-05-01 | 2001-05-07 | 106 | 17d | 0d |  | Lead Level Builder | 40h |
| 108 | 11.1.8.3 | Place / Script Units | 5d | 2001-05-08 | 2001-05-14 | 107 | 17d |  |  | Lead Level Builder | 40h |
| 109 | 11.1.9 | **Map (21-The Heartstone of Nyx)** | 12d | 2001-05-15 | 2001-05-30 | 105 | 17d | 0d |  |  | 96h |
| 110 | 11.1.9.1 | Sketch Design | 2d | 2001-05-15 | 2001-05-16 |  | 17d | 0d |  | Lead Level Builder | 16h |
| 111 | 11.1.9.2 | Build Map / Place Scenery | 5d | 2001-05-17 | 2001-05-23 | 110 | 17d | 0d |  | Lead Level Builder | 40h |
| 112 | 11.1.9.3 | Place / Script Units | 5d | 2001-05-24 | 2001-05-30 | 111 | 17d |  |  | Lead Level Builder | 40h |
| 113 | 11.1.10 | Incorporate Sound Level Assets | 6w | 2001-05-31 | 2001-07-11 | 109 | 17d | 3d | start no earlier than 2001-05-27 | Lead Level Builder | 240h |
| 114 | 11.1.11 | Training Level Scripting | 6w | 2001-07-17 | 2001-08-27 | 113 | 14d | 0d | finish no earlier than 2001-08-27 | Lead Level Builder | 240h |
| 115 | 11.1.12 | Playtest / Modify | 5w | 2001-08-28 | 2001-09-28 | 114 | 14d |  | finish no earlier than 2001-09-28 | Lead Level Builder | 200h |
| 116 | 11.2 | **LEVEL DESIGNER 1** | 196d | 2001-01-01 | 2001-09-28 |  | 14d |  |  |  | 1568h |
| 117 | 11.2.1 | **Map (8-The Road to Myrgard)** | 12d | 2001-01-01 | 2001-01-16 |  | 14d | 0d |  |  | 96h |
| 118 | 11.2.1.1 | Sketch Design | 2d | 2001-01-01 | 2001-01-02 |  | 14d | 0d |  | Level Builder 1 | 16h |
| 119 | 11.2.1.2 | Build Map / Place Scenery | 5d | 2001-01-03 | 2001-01-09 | 118 | 14d | 0d |  | Level Builder 1 | 40h |
| 120 | 11.2.1.3 | Place / Script Units | 5d | 2001-01-10 | 2001-01-16 | 119 | 14d |  |  | Level Builder 1 | 40h |
| 121 | 11.2.2 | **Map (3-Journey to Llancarfan)** | 12d | 2001-01-17 | 2001-02-01 | 117 | 14d | 0d |  |  | 96h |
| 122 | 11.2.2.1 | Sketch Design | 2d | 2001-01-17 | 2001-01-18 |  | 14d | 0d |  | Level Builder 1 | 16h |
| 123 | 11.2.2.2 | Build Map / Place Scenery | 5d | 2001-01-19 | 2001-01-25 | 122 | 14d | 0d |  | Level Builder 1 | 40h |
| 124 | 11.2.2.3 | Place / Script Units | 5d | 2001-01-26 | 2001-02-01 | 123 | 14d |  |  | Level Builder 1 | 40h |

| ID | WBS | Task | Duration | Start | Finish | Predecessors | Total slack | Free slack | Resources | Work |
| --- | --- | --- | --- | --- | --- | --- | --- | --- | --- | --- |
| 125 | 11.2.3 | **Map (5-Flight from the Dark)** | 12d | 2001-02-02 | 2001-02-19 | 121 | 14d | 0d |  | 96h |
| 126 | 11.2.3.1 | Sketch Design | 2d | 2001-02-02 | 2001-02-05 |  | 14d | 0d | Level Builder 1 | 16h |
| 127 | 11.2.3.2 | Build Map / Place Scenery | 5d | 2001-02-06 | 2001-02-12 | 126 | 14d | 0d | Level Builder 1 | 40h |
| 128 | 11.2.3.3 | Place / Script Units | 5d | 2001-02-13 | 2001-02-19 | 127 | 14d |  | Level Builder 1 | 40h |
| 129 | 11.2.4 | **Map (9-The Gates of Myrgard)** | 12d | 2001-02-20 | 2001-03-07 | 125 | 14d | 0d |  | 96h |
| 130 | 11.2.4.1 | Sketch Design | 2d | 2001-02-20 | 2001-02-21 |  | 14d | 0d | Level Builder 1 | 16h |
| 131 | 11.2.4.2 | Build Map / Place Scenery | 5d | 2001-02-22 | 2001-02-28 | 130 | 14d | 0d | Level Builder 1 | 40h |
| 132 | 11.2.4.3 | Place / Script Units | 5d | 2001-03-01 | 2001-03-07 | 131 | 14d |  | Level Builder 1 | 40h |
| 133 | 11.2.5 | **Map (10-Imprisonment)** | 12d | 2001-03-08 | 2001-03-23 | 129 | 14d | 0d |  | 96h |
| 134 | 11.2.5.1 | Sketch Design | 2d | 2001-03-08 | 2001-03-09 |  | 14d | 0d | Level Builder 1 | 16h |
| 135 | 11.2.5.2 | Build Map / Place Scenery | 5d | 2001-03-12 | 2001-03-16 | 134 | 14d | 0d | Level Builder 1 | 40h |
| 136 | 11.2.5.3 | Place / Script Units | 5d | 2001-03-19 | 2001-03-23 | 135 | 14d |  | Level Builder 1 | 40h |
| 137 | 11.2.6 | **Map (12-The Siege of Llancarfan)** | 12d | 2001-03-26 | 2001-04-10 | 133 | 14d | 0d |  | 96h |
| 138 | 11.2.6.1 | Sketch Design | 2d | 2001-03-26 | 2001-03-27 |  | 14d | 0d | Level Builder 1 | 16h |
| 139 | 11.2.6.2 | Build Map / Place Scenery | 5d | 2001-03-28 | 2001-04-03 | 138 | 14d | 0d | Level Builder 1 | 40h |
| 140 | 11.2.6.3 | Place / Script Units | 5d | 2001-04-04 | 2001-04-10 | 139 | 14d |  | Level Builder 1 | 40h |
| 141 | 11.2.7 | **Map (6-The Forgotten Lands)** | 12d | 2001-04-11 | 2001-04-26 | 137 | 14d | 0d |  | 96h |
| 142 | 11.2.7.1 | Sketch Design | 2d | 2001-04-11 | 2001-04-12 |  | 14d | 0d | Level Builder 1 | 16h |
| 143 | 11.2.7.2 | Build Map / Place Scenery | 5d | 2001-04-13 | 2001-04-19 | 142 | 14d | 0d | Level Builder 1 | 40h |
| 144 | 11.2.7.3 | Place / Script Units | 5d | 2001-04-20 | 2001-04-26 | 143 | 14d |  | Level Builder 1 | 40h |
| 145 | 11.2.8 | **Map (17-The Smith's Forge)** | 12d | 2001-04-27 | 2001-05-14 | 141 | 14d | 0d |  | 96h |
| 146 | 11.2.8.1 | Sketch Design | 2d | 2001-04-27 | 2001-04-30 |  | 14d | 0d | Level Builder 1 | 16h |
| 147 | 11.2.8.2 | Build Map / Place Scenery | 5d | 2001-05-01 | 2001-05-07 | 146 | 14d | 0d | Level Builder 1 | 40h |
| 148 | 11.2.8.3 | Place / Script Units | 5d | 2001-05-08 | 2001-05-14 | 147 | 14d |  | Level Builder 1 | 40h |

| ID | WBS | Task | Duration | Start | Finish | Predecessors | Total slack | Free slack | Constraint | Resources | Work |
| --- | --- | --- | --- | --- | --- | --- | --- | --- | --- | --- | --- |
| 149 | 11.2.9 | **Map (20-The Sunhammer)** | 12d | 2001-05-15 | 2001-05-30 | 145 | 14d | 0d |  |  | 96h |
| 150 | 11.2.9.1 | Sketch Design | 2d | 2001-05-15 | 2001-05-16 |  | 14d | 0d |  | Level Builder 1 | 16h |
| 151 | 11.2.9.2 | Build Map / Place Scenery | 5d | 2001-05-17 | 2001-05-23 | 150 | 14d | 0d |  | Level Builder 1 | 40h |
| 152 | 11.2.9.3 | Place / Script Units | 5d | 2001-05-24 | 2001-05-30 | 151 | 14d |  |  | Level Builder 1 | 40h |
| 153 | 11.2.10 | **Map (23-Fall of the Crown)** | 12d | 2001-05-31 | 2001-06-15 | 149 | 14d | 0d |  |  | 96h |
| 154 | 11.2.10.1 | Sketch Design | 2d | 2001-05-31 | 2001-06-01 |  | 14d | 0d |  | Level Builder 1 | 16h |
| 155 | 11.2.10.2 | Build Map / Place Scenery | 5d | 2001-06-04 | 2001-06-08 | 154 | 14d | 0d |  | Level Builder 1 | 40h |
| 156 | 11.2.10.3 | Place / Script Units | 5d | 2001-06-11 | 2001-06-15 | 155 | 14d |  |  | Level Builder 1 | 40h |
| 157 | 11.2.11 | **Map (25-The Traitor)** | 12d | 2001-06-18 | 2001-07-03 | 153 | 14d | 0d |  |  | 96h |
| 158 | 11.2.11.1 | Sketch Design | 2d | 2001-06-18 | 2001-06-19 |  | 14d | 0d |  | Level Builder 1 | 16h |
| 159 | 11.2.11.2 | Build Map / Place Scenery | 5d | 2001-06-20 | 2001-06-26 | 158 | 14d | 0d |  | Level Builder 1 | 40h |
| 160 | 11.2.11.3 | Place / Script Units | 5d | 2001-06-27 | 2001-07-03 | 159 | 14d |  |  | Level Builder 1 | 40h |
| 161 | 11.2.12 | **Map (Cutscene-Moagim's Trap)** | 12d | 2001-07-04 | 2001-07-19 | 157 | 14d | 0d |  |  | 96h |
| 162 | 11.2.12.1 | Sketch Design | 2d | 2001-07-04 | 2001-07-05 |  | 14d | 0d |  | Level Builder 1 | 16h |
| 163 | 11.2.12.2 | Build Map / Place Scenery | 5d | 2001-07-06 | 2001-07-12 | 162 | 14d | 0d |  | Level Builder 1 | 40h |
| 164 | 11.2.12.3 | Place / Script Units | 5d | 2001-07-13 | 2001-07-19 | 163 | 14d |  |  | Level Builder 1 | 40h |
| 165 | 11.2.13 | **Map (Cutscene-Imperial War Room)** | 12d | 2001-07-20 | 2001-08-06 | 161 | 14d | 0d |  |  | 96h |
| 166 | 11.2.13.1 | Sketch Design | 2d | 2001-07-20 | 2001-07-23 |  | 14d | 0d |  | Level Builder 1 | 16h |
| 167 | 11.2.13.2 | Build Map / Place Scenery | 5d | 2001-07-24 | 2001-07-30 | 166 | 14d | 0d |  | Level Builder 1 | 40h |
| 168 | 11.2.13.3 | Place / Script Units | 5d | 2001-07-31 | 2001-08-06 | 167 | 14d |  |  | Level Builder 1 | 40h |
| 169 | 11.2.14 | Cutscene Scripting | 3w | 2001-08-07 | 2001-08-27 | 165 | 14d | 0d | start no earlier than 2001-08-05 | Level Builder 1 | 120h |
| 170 | 11.2.15 | Playtest / Modify | 5w | 2001-08-28 | 2001-09-28 | 169 | 14d |  | finish no earlier than 2001-09-28 | Level Builder 1 | 200h |
| 171 | 11.3 | **LEVEL DESIGNER 2** | 196d | 2001-01-01 | 2001-09-28 |  | 14d |  |  |  | 1568h |
| 172 | 11.3.1 | **Map (2-The Nest)** | 12d | 2001-01-01 | 2001-01-16 |  | 14d | 0d |  |  | 96h |
| 173 | 11.3.1.1 | Sketch Design | 2d | 2001-01-01 | 2001-01-02 |  | 14d | 0d |  | Level Builder 2 | 16h |
| 174 | 11.3.1.2 | Build Map / Place Scenery | 5d | 2001-01-03 | 2001-01-09 | 173 | 14d | 0d |  | Level Builder 2 | 40h |
| 175 | 11.3.1.3 | Place / Script Units | 5d | 2001-01-10 | 2001-01-16 | 174 | 14d |  |  | Level Builder 2 | 40h |

| ID | WBS | Task | Duration | Start | Finish | Predecessors | Total slack | Free slack | Resources | Work |
| --- | --- | --- | --- | --- | --- | --- | --- | --- | --- | --- |
| 176 | 11.3.2 | **Map (4-The Pack-Mage)** | 12d | 2001-01-17 | 2001-02-01 | 172 | 14d | 0d |  | 96h |
| 177 | 11.3.2.1 | Sketch Design | 2d | 2001-01-17 | 2001-01-18 |  | 14d | 0d | Level Builder 2 | 16h |
| 178 | 11.3.2.2 | Build Map / Place Scenery | 5d | 2001-01-19 | 2001-01-25 | 177 | 14d | 0d | Level Builder 2 | 40h |
| 179 | 11.3.2.3 | Place / Script Units | 5d | 2001-01-26 | 2001-02-01 | 178 | 14d |  | Level Builder 2 | 40h |
| 180 | 11.3.3 | **Map (1-The Defense of Yursgrad)** | 12d | 2001-02-02 | 2001-02-19 | 176 | 14d | 0d |  | 96h |
| 181 | 11.3.3.1 | Sketch Design | 2d | 2001-02-02 | 2001-02-05 |  | 14d | 0d | Level Builder 2 | 16h |
| 182 | 11.3.3.2 | Build Map / Place Scenery | 5d | 2001-02-06 | 2001-02-12 | 181 | 14d | 0d | Level Builder 2 | 40h |
| 183 | 11.3.3.3 | Place / Script Units | 5d | 2001-02-13 | 2001-02-19 | 182 | 14d |  | Level Builder 2 | 40h |
| 184 | 11.3.4 | **Map (13-Rod of the Callieach)** | 12d | 2001-02-20 | 2001-03-07 | 180 | 14d | 0d |  | 96h |
| 185 | 11.3.4.1 | Sketch Design | 2d | 2001-02-20 | 2001-02-21 |  | 14d | 0d | Level Builder 2 | 16h |
| 186 | 11.3.4.2 | Build Map / Place Scenery | 5d | 2001-02-22 | 2001-02-28 | 185 | 14d | 0d | Level Builder 2 | 40h |
| 187 | 11.3.4.3 | Place / Script Units | 5d | 2001-03-01 | 2001-03-07 | 186 | 14d |  | Level Builder 2 | 40h |
| 188 | 11.3.5 | **Map (11-The Eye of Thalor)** | 12d | 2001-03-08 | 2001-03-23 | 184 | 14d | 0d |  | 96h |
| 189 | 11.3.5.1 | Sketch Design | 2d | 2001-03-08 | 2001-03-09 |  | 14d | 0d | Level Builder 2 | 16h |
| 190 | 11.3.5.2 | Build Map / Place Scenery | 5d | 2001-03-12 | 2001-03-16 | 189 | 14d | 0d | Level Builder 2 | 40h |
| 191 | 11.3.5.3 | Place / Script Units | 5d | 2001-03-19 | 2001-03-23 | 190 | 14d |  | Level Builder 2 | 40h |
| 192 | 11.3.6 | **Map (14-The Bonds of the Oghre)** | 12d | 2001-03-26 | 2001-04-10 | 188 | 14d | 0d |  | 96h |
| 193 | 11.3.6.1 | Sketch Design | 2d | 2001-03-26 | 2001-03-27 |  | 14d | 0d | Level Builder 2 | 16h |
| 194 | 11.3.6.2 | Build Map / Place Scenery | 5d | 2001-03-28 | 2001-04-03 | 193 | 14d | 0d | Level Builder 2 | 40h |
| 195 | 11.3.6.3 | Place / Script Units | 5d | 2001-04-04 | 2001-04-10 | 194 | 14d |  | Level Builder 2 | 40h |
| 196 | 11.3.7 | **Map (7-The Crypt of Mazzarin)** | 12d | 2001-04-11 | 2001-04-26 | 192 | 14d | 0d |  | 96h |
| 197 | 11.3.7.1 | Sketch Design | 2d | 2001-04-11 | 2001-04-12 |  | 14d | 0d | Level Builder 2 | 16h |
| 198 | 11.3.7.2 | Build Map / Place Scenery | 5d | 2001-04-13 | 2001-04-19 | 197 | 14d | 0d | Level Builder 2 | 40h |
| 199 | 11.3.7.3 | Place / Script Units | 5d | 2001-04-20 | 2001-04-26 | 198 | 14d |  | Level Builder 2 | 40h |

| ID | WBS | Task | Duration | Start | Finish | Predecessors | Total slack | Free slack | Constraint | Resources | Work |
| --- | --- | --- | --- | --- | --- | --- | --- | --- | --- | --- | --- |
| 200 | 11.3.8 | **Map (18-The Spider God)** | 12d | 2001-04-27 | 2001-05-14 | 196 | 14d | 0d |  |  | 96h |
| 201 | 11.3.8.1 | Sketch Design | 2d | 2001-04-27 | 2001-04-30 |  | 14d | 0d |  | Level Builder 2 | 16h |
| 202 | 11.3.8.2 | Build Map / Place Scenery | 5d | 2001-05-01 | 2001-05-07 | 201 | 14d | 0d |  | Level Builder 2 | 40h |
| 203 | 11.3.8.3 | Place / Script Units | 5d | 2001-05-08 | 2001-05-14 | 202 | 14d |  |  | Level Builder 2 | 40h |
| 204 | 11.3.9 | **Map (22-Dream Duel)** | 12d | 2001-05-15 | 2001-05-30 | 200 | 14d | 0d |  |  | 96h |
| 205 | 11.3.9.1 | Sketch Design | 2d | 2001-05-15 | 2001-05-16 |  | 14d | 0d |  | Level Builder 2 | 16h |
| 206 | 11.3.9.2 | Build Map / Place Scenery | 5d | 2001-05-17 | 2001-05-23 | 205 | 14d | 0d |  | Level Builder 2 | 40h |
| 207 | 11.3.9.3 | Place / Script Units | 5d | 2001-05-24 | 2001-05-30 | 206 | 14d |  |  | Level Builder 2 | 40h |
| 208 | 11.3.10 | **Map (24-Vengeance)** | 12d | 2001-05-31 | 2001-06-15 | 204 | 14d | 0d |  |  | 96h |
| 209 | 11.3.10.1 | Sketch Design | 2d | 2001-05-31 | 2001-06-01 |  | 14d | 0d |  | Level Builder 2 | 16h |
| 210 | 11.3.10.2 | Build Map / Place Scenery | 5d | 2001-06-04 | 2001-06-08 | 209 | 14d | 0d |  | Level Builder 2 | 40h |
| 211 | 11.3.10.3 | Place / Script Units | 5d | 2001-06-11 | 2001-06-15 | 210 | 14d |  |  | Level Builder 2 | 40h |
| 212 | 11.3.11 | **Map (Cutscene-Imperial Chambers)** | 12d | 2001-06-18 | 2001-07-03 | 208 | 14d | 0d |  |  | 96h |
| 213 | 11.3.11.1 | Sketch Design | 2d | 2001-06-18 | 2001-06-19 |  | 14d | 0d |  | Level Builder 2 | 16h |
| 214 | 11.3.11.2 | Build Map / Place Scenery | 5d | 2001-06-20 | 2001-06-26 | 213 | 14d | 0d |  | Level Builder 2 | 40h |
| 215 | 11.3.11.3 | Place / Script Units | 5d | 2001-06-27 | 2001-07-03 | 214 | 14d |  |  | Level Builder 2 | 40h |
| 216 | 11.3.12 | **Map (Cutscene-The Streets of Llancarfan)** | 12d | 2001-07-04 | 2001-07-19 | 212 | 14d | 0d |  |  | 96h |
| 217 | 11.3.12.1 | Sketch Design | 2d | 2001-07-04 | 2001-07-05 |  | 14d | 0d |  | Level Builder 2 | 16h |
| 218 | 11.3.12.2 | Build Map / Place Scenery | 5d | 2001-07-06 | 2001-07-12 | 217 | 14d | 0d |  | Level Builder 2 | 40h |
| 219 | 11.3.12.3 | Place / Script Units | 5d | 2001-07-13 | 2001-07-19 | 218 | 14d |  |  | Level Builder 2 | 40h |
| 220 | 11.3.13 | **Map (Cutscene-Valley of the Red Seal)** | 12d | 2001-07-20 | 2001-08-06 | 216 | 14d | 0d |  |  | 96h |
| 221 | 11.3.13.1 | Sketch Design | 2d | 2001-07-20 | 2001-07-23 |  | 14d | 0d |  | Level Builder 2 | 16h |
| 222 | 11.3.13.2 | Build Map / Place Scenery | 5d | 2001-07-24 | 2001-07-30 | 221 | 14d | 0d |  | Level Builder 2 | 40h |
| 223 | 11.3.13.3 | Place / Script Units | 5d | 2001-07-31 | 2001-08-06 | 222 | 14d |  |  | Level Builder 2 | 40h |
| 224 | 11.3.14 | Cutscene Scripting | 3w | 2001-08-07 | 2001-08-27 | 220 | 14d | 0d |  | Level Builder 2 | 120h |
| 225 | 11.3.15 | Playtest / Modify | 5w | 2001-08-28 | 2001-09-28 | 224 | 14d |  | finish no earlier than 2001-09-28 | Level Builder 2 | 200h |

| ID | WBS | Task | Duration | Start | Finish | Predecessors | Total slack | Free slack | Resources | Work |
| --- | --- | --- | --- | --- | --- | --- | --- | --- | --- | --- |
| 226 | 12 | **ART ASSETS** | 196d | 2001-01-01 | 2001-09-28 |  | 14d |  |  | 9336h |
| 227 | 12.1 | **SENIOR ARTIST** | 196d | 2001-01-01 | 2001-09-28 |  | 14d |  |  | 1520h |
| 228 | 12.1.1 | World Map Picture | 20d | 2001-01-01 | 2001-01-26 |  | 20d | 0d | Senior Artist | 160h |
| 229 | 12.1.2 | **Unit Model (Spearmen)** | 10d | 2001-01-29 | 2001-02-09 | 228 | 20d | 0d |  | 80h |
| 230 | 12.1.2.1 | Low-Poly Model | 3d | 2001-01-29 | 2001-01-31 |  | 20d | 0d | Senior Artist | 24h |
| 231 | 12.1.2.2 | Animation | 5d | 2001-02-01 | 2001-02-07 | 230 | 20d | 0d | Senior Artist | 40h |
| 232 | 12.1.2.3 | Miscellaneous | 2d | 2001-02-08 | 2001-02-09 | 231 | 20d |  | Senior Artist | 16h |
| 233 | 12.1.3 | Level Terrain (3-Journey to Llancarfan) | 1w | 2001-02-12 | 2001-02-16 | 229 | 20d | 0d | Senior Artist | 40h |
| 234 | 12.1.4 | Level Terrain (Netplay-Catacombs) | 1w | 2001-02-19 | 2001-02-23 | 233 | 20d | 0d | Senior Artist | 40h |
| 235 | 12.1.5 | **Unit Model (Heron Guard)** | 10d | 2001-02-26 | 2001-03-09 | 234 | 20d | 0d |  | 80h |
| 236 | 12.1.5.1 | Low-Poly Model | 3d | 2001-02-26 | 2001-02-28 |  | 20d | 0d | Senior Artist | 24h |
| 237 | 12.1.5.2 | Animation | 5d | 2001-03-01 | 2001-03-07 | 236 | 20d | 0d | Senior Artist | 40h |
| 238 | 12.1.5.3 | Miscellaneous | 2d | 2001-03-08 | 2001-03-09 | 237 | 20d |  | Senior Artist | 16h |
| 239 | 12.1.6 | Level Terrain (5-Flight from the Dark) | 1w | 2001-03-12 | 2001-03-16 | 235 | 20d | 0d | Senior Artist | 40h |
| 240 | 12.1.7 | Level Terrain (Netplay-Desert) | 1w | 2001-03-19 | 2001-03-23 | 239 | 20d | 0d | Senior Artist | 40h |
| 241 | 12.1.8 | Level Terrain (9-Gates of Myrgard) | 1w | 2001-03-26 | 2001-03-30 | 240 | 20d | 0d | Senior Artist | 40h |
| 242 | 12.1.9 | Level Terrain (Netplay-Jungle) | 1w | 2001-04-02 | 2001-04-06 | 241 | 20d | 0d | Senior Artist | 40h |
| 243 | 12.1.10 | **Unit Model (Oghre)** | 10d | 2001-04-09 | 2001-04-20 | 242 | 20d | 0d |  | 80h |
| 244 | 12.1.10.1 | Low-Poly Model | 3d | 2001-04-09 | 2001-04-11 |  | 20d | 0d | Senior Artist | 24h |
| 245 | 12.1.10.2 | Animation | 5d | 2001-04-12 | 2001-04-18 | 244 | 20d | 0d | Senior Artist | 40h |
| 246 | 12.1.10.3 | Miscellaneous | 2d | 2001-04-19 | 2001-04-20 | 245 | 20d |  | Senior Artist | 16h |
| 247 | 12.1.11 | Level Terrain (11-Eye of Thalor) | 1w | 2001-04-23 | 2001-04-27 | 243 | 20d | 0d | Senior Artist | 40h |
| 248 | 12.1.12 | Level Terrain (14-Bonds of the Oghre) | 1w | 2001-04-30 | 2001-05-04 | 247 | 20d | 0d | Senior Artist | 40h |
| 249 | 12.1.13 | Level Terrain (15-Rebellion) | 1w | 2001-05-07 | 2001-05-11 | 248 | 20d | 0d | Senior Artist | 40h |
| 250 | 12.1.14 | Level Terrain (Netplay-Volcano) | 1w | 2001-05-14 | 2001-05-18 | 249 | 20d | 0d | Senior Artist | 40h |

| ID | WBS | Task | Duration | Start | Finish | Predecessors | Total slack | Free slack | Constraint | Resources | Work |
| --- | --- | --- | --- | --- | --- | --- | --- | --- | --- | --- | --- |
| 251 | 12.1.15 | **Unit Model (Mazzarin)** | 10d | 2001-05-21 | 2001-06-01 | 250 | 20d | 0d |  |  | 80h |
| 252 | 12.1.15.1 | Low-Poly Model | 3d | 2001-05-21 | 2001-05-23 |  | 20d | 0d |  | Senior Artist | 24h |
| 253 | 12.1.15.2 | Animation | 5d | 2001-05-24 | 2001-05-30 | 252 | 20d | 0d |  | Senior Artist | 40h |
| 254 | 12.1.15.3 | Miscellaneous | 2d | 2001-05-31 | 2001-06-01 | 253 | 20d |  |  | Senior Artist | 16h |
| 255 | 12.1.16 | Level Terrain (7-Crypt of Mazzarin) | 1w | 2001-06-04 | 2001-06-08 | 251 | 20d | 0d |  | Senior Artist | 40h |
| 256 | 12.1.17 | Level Terrain (18-The Spider God) | 1w | 2001-06-11 | 2001-06-15 | 255 | 20d | 0d |  | Senior Artist | 40h |
| 257 | 12.1.18 | Level Terrain (Netplay-Fortress) | 1w | 2001-06-18 | 2001-06-22 | 256 | 20d | 0d |  | Senior Artist | 40h |
| 258 | 12.1.19 | Level Terrain (Dream Duel) | 1w | 2001-06-25 | 2001-06-29 | 257 | 20d | 0d |  | Senior Artist | 40h |
| 259 | 12.1.20 | **Unit Model (The Watcher)** | 10d | 2001-07-02 | 2001-07-13 | 258 | 20d | 0d |  |  | 80h |
| 260 | 12.1.20.1 | Low-Poly Model | 3d | 2001-07-02 | 2001-07-04 |  | 20d | 0d |  | Senior Artist | 24h |
| 261 | 12.1.20.2 | Animation | 5d | 2001-07-05 | 2001-07-11 | 260 | 20d | 0d |  | Senior Artist | 40h |
| 262 | 12.1.20.3 | Miscellaneous | 2d | 2001-07-12 | 2001-07-13 | 261 | 20d |  |  | Senior Artist | 16h |
| 263 | 12.1.21 | Level Terrain (23-Fall of the Crown) | 1w | 2001-07-16 | 2001-07-20 | 259 | 20d | 0d |  | Senior Artist | 40h |
| 264 | 12.1.22 | Level Terrain (25-The Traitor) | 1w | 2001-07-23 | 2001-07-27 | 263 | 20d | 0d |  | Senior Artist | 40h |
| 265 | 12.1.23 | Level Terrain (Cutscene-Moagim's Trap) | 1w | 2001-07-30 | 2001-08-03 | 264 | 20d | 0d |  | Senior Artist | 40h |
| 266 | 12.1.24 | Level Terrain (Cutscene-Streets of Llancarfan) | 1w | 2001-08-06 | 2001-08-10 | 265 | 20d | 0d |  | Senior Artist | 40h |
| 267 | 12.1.25 | Level Terrain (Cutscene-Imperial War room) | 1w | 2001-08-13 | 2001-08-17 | 266 | 20d | 0d |  | Senior Artist | 40h |
| 268 | 12.1.26 | Level Terrain (Cutscene-Valley of the Red Seal) | 1w | 2001-08-20 | 2001-08-24 | 267 | 20d | 6d |  | Senior Artist | 40h |
| 269 | 12.1.27 | Touch-up | 4w | 2001-09-03 | 2001-09-28 | 268 | 14d |  | finish no earlier than 2001-09-28 | Senior Artist | 160h |
| 270 | 12.2 | **MODELER / ANIMATOR 1** | 196d | 2001-01-01 | 2001-09-28 |  | 14d |  |  |  | 1568h |
| 271 | 12.2.1 | **Unit Model (Archers)** | 10d | 2001-01-01 | 2001-01-12 |  | 14d | 0d |  |  | 80h |
| 272 | 12.2.1.1 | Low-Poly Model | 3d | 2001-01-01 | 2001-01-03 |  | 14d | 0d |  | Modeler/Animator 1 | 24h |
| 273 | 12.2.1.2 | Animation | 5d | 2001-01-04 | 2001-01-10 | 272 | 14d | 0d |  | Modeler/Animator 1 | 40h |
| 274 | 12.2.1.3 | Miscellaneous | 2d | 2001-01-11 | 2001-01-12 | 273 | 14d |  |  | Modeler/Animator 1 | 16h |

| ID | WBS | Task | Duration | Start | Finish | Predecessors | Total slack | Free slack | Resources | Work |
| --- | --- | --- | --- | --- | --- | --- | --- | --- | --- | --- |
| 275 | 12.2.2 | **Unit Model (Berserks)** | 10d | 2001-01-15 | 2001-01-26 | 271 | 14d | 0d |  | 80h |
| 276 | 12.2.2.1 | Low-Poly Model | 3d | 2001-01-15 | 2001-01-17 |  | 14d | 0d | Modeler/Animator 1 | 24h |
| 277 | 12.2.2.2 | Animation | 5d | 2001-01-18 | 2001-01-24 | 276 | 14d | 0d | Modeler/Animator 1 | 40h |
| 278 | 12.2.2.3 | Miscellaneous | 2d | 2001-01-25 | 2001-01-26 | 277 | 14d |  | Modeler/Animator 1 | 16h |
| 279 | 12.2.3 | **Unit Model (Peasants)** | 10d | 2001-01-29 | 2001-02-09 | 275 | 14d | 0d |  | 80h |
| 280 | 12.2.3.1 | Low-Poly Model | 3d | 2001-01-29 | 2001-01-31 |  | 14d | 0d | Modeler/Animator 1 | 24h |
| 281 | 12.2.3.2 | Animation | 5d | 2001-02-01 | 2001-02-07 | 280 | 14d | 0d | Modeler/Animator 1 | 40h |
| 282 | 12.2.3.3 | Miscellaneous | 2d | 2001-02-08 | 2001-02-09 | 281 | 14d |  | Modeler/Animator 1 | 16h |
| 283 | 12.2.4 | **Unit Model (Soulless)** | 10d | 2001-02-12 | 2001-02-23 | 279 | 14d | 0d |  | 80h |
| 284 | 12.2.4.1 | Low-Poly Model | 3d | 2001-02-12 | 2001-02-14 |  | 14d | 0d | Modeler/Animator 1 | 24h |
| 285 | 12.2.4.2 | Animation | 5d | 2001-02-15 | 2001-02-21 | 284 | 14d | 0d | Modeler/Animator 1 | 40h |
| 286 | 12.2.4.3 | Miscellaneous | 2d | 2001-02-22 | 2001-02-23 | 285 | 14d |  | Modeler/Animator 1 | 16h |
| 287 | 12.2.5 | **Unit Model (Connacht)** | 10d | 2001-02-26 | 2001-03-09 | 283 | 14d | 0d |  | 80h |
| 288 | 12.2.5.1 | Low-Poly Model | 3d | 2001-02-26 | 2001-02-28 |  | 14d | 0d | Modeler/Animator 1 | 24h |
| 289 | 12.2.5.2 | Animation | 5d | 2001-03-01 | 2001-03-07 | 288 | 14d | 0d | Modeler/Animator 1 | 40h |
| 290 | 12.2.5.3 | Miscellaneous | 2d | 2001-03-08 | 2001-03-09 | 289 | 14d |  | Modeler/Animator 1 | 16h |
| 291 | 12.2.6 | **Unit Model (Damas)** | 10d | 2001-03-12 | 2001-03-23 | 287 | 14d | 0d |  | 80h |
| 292 | 12.2.6.1 | Low-Poly Model | 3d | 2001-03-12 | 2001-03-14 |  | 14d | 0d | Modeler/Animator 1 | 24h |
| 293 | 12.2.6.2 | Animation | 5d | 2001-03-15 | 2001-03-21 | 292 | 14d | 0d | Modeler/Animator 1 | 40h |
| 294 | 12.2.6.3 | Miscellaneous | 2d | 2001-03-22 | 2001-03-23 | 293 | 14d |  | Modeler/Animator 1 | 16h |
| 295 | 12.2.7 | **Unit Model (Dwarven Demolitionists)** | 10d | 2001-03-26 | 2001-04-06 | 291 | 14d | 0d |  | 80h |
| 296 | 12.2.7.1 | Low-Poly Model | 3d | 2001-03-26 | 2001-03-28 |  | 14d | 0d | Modeler/Animator 1 | 24h |
| 297 | 12.2.7.2 | Animation | 5d | 2001-03-29 | 2001-04-04 | 296 | 14d | 0d | Modeler/Animator 1 | 40h |
| 298 | 12.2.7.3 | Miscellaneous | 2d | 2001-04-05 | 2001-04-06 | 297 | 14d |  | Modeler/Animator 1 | 16h |

| ID | WBS | Task | Duration | Start | Finish | Predecessors | Total slack | Free slack | Resources | Work |
| --- | --- | --- | --- | --- | --- | --- | --- | --- | --- | --- |
| 299 | 12.2.8 | **Unit Model (Trow Iron Warrior)** | 10d | 2001-04-09 | 2001-04-20 | 295 | 14d | 0d |  | 80h |
| 300 | 12.2.8.1 | Low-Poly Model | 3d | 2001-04-09 | 2001-04-11 |  | 14d | 0d | Modeler/Animator 1 | 24h |
| 301 | 12.2.8.2 | Animation | 5d | 2001-04-12 | 2001-04-18 | 300 | 14d | 0d | Modeler/Animator 1 | 40h |
| 302 | 12.2.8.3 | Miscellaneous | 2d | 2001-04-19 | 2001-04-20 | 301 | 14d |  | Modeler/Animator 1 | 16h |
| 303 | 12.2.9 | **Unit Model (Ravanna)** | 10d | 2001-04-23 | 2001-05-04 | 299 | 14d | 0d |  | 80h |
| 304 | 12.2.9.1 | Low-Poly Model | 3d | 2001-04-23 | 2001-04-25 |  | 14d | 0d | Modeler/Animator 1 | 24h |
| 305 | 12.2.9.2 | Animation | 5d | 2001-04-26 | 2001-05-02 | 304 | 14d | 0d | Modeler/Animator 1 | 40h |
| 306 | 12.2.9.3 | Miscellaneous | 2d | 2001-05-03 | 2001-05-04 | 305 | 14d |  | Modeler/Animator 1 | 16h |
| 307 | 12.2.10 | **Unit Model (Dwarven Axe-Warriors)** | 10d | 2001-05-07 | 2001-05-18 | 303 | 14d | 0d |  | 80h |
| 308 | 12.2.10.1 | Low-Poly Model | 3d | 2001-05-07 | 2001-05-09 |  | 14d | 0d | Modeler/Animator 1 | 24h |
| 309 | 12.2.10.2 | Animation | 5d | 2001-05-10 | 2001-05-16 | 308 | 14d | 0d | Modeler/Animator 1 | 40h |
| 310 | 12.2.10.3 | Miscellaneous | 2d | 2001-05-17 | 2001-05-18 | 309 | 14d |  | Modeler/Animator 1 | 16h |
| 311 | 12.2.11 | **Unit Model (Dwarven Smiths)** | 10d | 2001-05-21 | 2001-06-01 | 307 | 14d | 0d |  | 80h |
| 312 | 12.2.11.1 | Low-Poly Model | 3d | 2001-05-21 | 2001-05-23 |  | 14d | 0d | Modeler/Animator 1 | 24h |
| 313 | 12.2.11.2 | Animation | 5d | 2001-05-24 | 2001-05-30 | 312 | 14d | 0d | Modeler/Animator 1 | 40h |
| 314 | 12.2.11.3 | Miscellaneous | 2d | 2001-05-31 | 2001-06-01 | 313 | 14d |  | Modeler/Animator 1 | 16h |
| 315 | 12.2.12 | **Unit Model (Mahir)** | 10d | 2001-06-04 | 2001-06-15 | 311 | 14d | 0d |  | 80h |
| 316 | 12.2.12.1 | Low-Poly Model | 3d | 2001-06-04 | 2001-06-06 |  | 14d | 0d | Modeler/Animator 1 | 24h |
| 317 | 12.2.12.2 | Animation | 5d | 2001-06-07 | 2001-06-13 | 316 | 14d | 0d | Modeler/Animator 1 | 40h |
| 318 | 12.2.12.3 | Miscellaneous | 2d | 2001-06-14 | 2001-06-15 | 317 | 14d |  | Modeler/Animator 1 | 16h |
| 319 | 12.2.13 | **Unit Model (Moagim Reborn)** | 10d | 2001-06-18 | 2001-06-29 | 315 | 14d | 0d |  | 80h |
| 320 | 12.2.13.1 | Low-Poly Model | 3d | 2001-06-18 | 2001-06-20 |  | 14d | 0d | Modeler/Animator 1 | 24h |
| 321 | 12.2.13.2 | Animation | 5d | 2001-06-21 | 2001-06-27 | 320 | 14d | 0d | Modeler/Animator 1 | 40h |
| 322 | 12.2.13.3 | Miscellaneous | 2d | 2001-06-28 | 2001-06-29 | 321 | 14d |  | Modeler/Animator 1 | 16h |

| ID | WBS | Task | Duration | Start | Finish | Predecessors | Total slack | Free slack | Constraint | Resources | Work |
| --- | --- | --- | --- | --- | --- | --- | --- | --- | --- | --- | --- |
| 323 | 12.2.14 | **Unit Model (Emperor Leitrim)** | 10d | 2001-07-02 | 2001-07-13 | 319 | 14d | 0d |  |  | 80h |
| 324 | 12.2.14.1 | Low-Poly Model | 3d | 2001-07-02 | 2001-07-04 |  | 14d | 0d |  | Modeler/Animator 1 | 24h |
| 325 | 12.2.14.2 | Animation | 5d | 2001-07-05 | 2001-07-11 | 324 | 14d | 0d |  | Modeler/Animator 1 | 40h |
| 326 | 12.2.14.3 | Miscellaneous | 2d | 2001-07-12 | 2001-07-13 | 325 | 14d |  |  | Modeler/Animator 1 | 16h |
| 327 | 12.2.15 | **Unit Model (Spider Cultists)** | 10d | 2001-07-16 | 2001-07-27 | 323 | 14d | 0d |  |  | 80h |
| 328 | 12.2.15.1 | Low-Poly Model | 3d | 2001-07-16 | 2001-07-18 |  | 14d | 0d |  | Modeler/Animator 1 | 24h |
| 329 | 12.2.15.2 | Animation | 5d | 2001-07-19 | 2001-07-25 | 328 | 14d | 0d |  | Modeler/Animator 1 | 40h |
| 330 | 12.2.15.3 | Miscellaneous | 2d | 2001-07-26 | 2001-07-27 | 329 | 14d |  |  | Modeler/Animator 1 | 16h |
| 331 | 12.2.16 | **Unit Modl (Deer)** | 10d | 2001-07-30 | 2001-08-10 | 327 | 14d | 0d |  |  | 80h |
| 332 | 12.2.16.1 | Low-Poly Model | 3d | 2001-07-30 | 2001-08-01 |  | 14d | 0d |  | Modeler/Animator 1 | 24h |
| 333 | 12.2.16.2 | Animation | 5d | 2001-08-02 | 2001-08-08 | 332 | 14d | 0d |  | Modeler/Animator 1 | 40h |
| 334 | 12.2.16.3 | Miscellaneous | 2d | 2001-08-09 | 2001-08-10 | 333 | 14d |  |  | Modeler/Animator 1 | 16h |
| 335 | 12.2.17 | **Unit Model (Springal / Hawk)** | 10d | 2001-08-13 | 2001-08-24 | 331 | 14d | 0d |  |  | 80h |
| 336 | 12.2.17.1 | Low-Poly Model | 3d | 2001-08-13 | 2001-08-15 |  | 14d | 0d |  | Modeler/Animator 1 | 24h |
| 337 | 12.2.17.2 | Animation | 5d | 2001-08-16 | 2001-08-22 | 336 | 14d | 0d |  | Modeler/Animator 1 | 40h |
| 338 | 12.2.17.3 | Miscellaneous | 2d | 2001-08-23 | 2001-08-24 | 337 | 14d |  |  | Modeler/Animator 1 | 16h |
| 339 | 12.2.18 | Touch-up | 5.2w | 2001-08-27 | 2001-09-28 | 335 | 14d |  | start no earlier than 2001-08-27 | Modeler/Animator 1 | 208h |
| 340 | 12.3 | **MODELER / ANIMATOR 2** | 196d | 2001-01-01 | 2001-09-28 |  | 14d |  |  |  | 1568h |
| 341 | 12.3.1 | **Unit Model (Soldiers)** | 10d | 2001-01-01 | 2001-01-12 |  | 14d | 0d |  |  | 80h |
| 342 | 12.3.1.1 | Low-Poly Model | 3d | 2001-01-01 | 2001-01-03 |  | 14d | 0d |  | Modeler/Animator 2 | 24h |
| 343 | 12.3.1.2 | Animation | 5d | 2001-01-04 | 2001-01-10 | 342 | 14d | 0d |  | Modeler/Animator 2 | 40h |
| 344 | 12.3.1.3 | Miscellaneous | 2d | 2001-01-11 | 2001-01-12 | 343 | 14d |  |  | Modeler/Animator 2 | 16h |
| 345 | 12.3.2 | **Unit Model (Myrkridia)** | 10d | 2001-01-15 | 2001-01-26 | 341 | 14d | 0d |  |  | 80h |
| 346 | 12.3.2.1 | Low-Poly Model | 3d | 2001-01-15 | 2001-01-17 |  | 14d | 0d |  | Modeler/Animator 2 | 24h |
| 347 | 12.3.2.2 | Animation | 5d | 2001-01-18 | 2001-01-24 | 346 | 14d | 0d |  | Modeler/Animator 2 | 40h |
| 348 | 12.3.2.3 | Miscellaneous | 2d | 2001-01-25 | 2001-01-26 | 347 | 14d |  |  | Modeler/Animator 2 | 16h |

| ID | WBS | Task | Duration | Start | Finish | Predecessors | Total slack | Free slack | Resources | Work |
| --- | --- | --- | --- | --- | --- | --- | --- | --- | --- | --- |
| 349 | 12.3.3 | **Unit Model (Thrall)** | 10d | 2001-01-29 | 2001-02-09 | 345 | 14d | 0d |  | 80h |
| 350 | 12.3.3.1 | Low-Poly Model | 3d | 2001-01-29 | 2001-01-31 |  | 14d | 0d | Modeler/Animator 2 | 24h |
| 351 | 12.3.3.2 | Animation | 5d | 2001-02-01 | 2001-02-07 | 350 | 14d | 0d | Modeler/Animator 2 | 40h |
| 352 | 12.3.3.3 | Miscellaneous | 2d | 2001-02-08 | 2001-02-09 | 351 | 14d |  | Modeler/Animator 2 | 16h |
| 353 | 12.3.4 | **Unit Model (Wights)** | 10d | 2001-02-12 | 2001-02-23 | 349 | 14d | 0d |  | 80h |
| 354 | 12.3.4.1 | Low-Poly Model | 3d | 2001-02-12 | 2001-02-14 |  | 14d | 0d | Modeler/Animator 2 | 24h |
| 355 | 12.3.4.2 | Animation | 5d | 2001-02-15 | 2001-02-21 | 354 | 14d | 0d | Modeler/Animator 2 | 40h |
| 356 | 12.3.4.3 | Miscellaneous | 2d | 2001-02-22 | 2001-02-23 | 355 | 14d |  | Modeler/Animator 2 | 16h |
| 357 | 12.3.5 | **Unit Model (Myrkridian Giant)** | 10d | 2001-02-26 | 2001-03-09 | 353 | 14d | 0d |  | 80h |
| 358 | 12.3.5.1 | Low-Poly Model | 3d | 2001-02-26 | 2001-02-28 |  | 14d | 0d | Modeler/Animator 2 | 24h |
| 359 | 12.3.5.2 | Animation | 5d | 2001-03-01 | 2001-03-07 | 358 | 14d | 0d | Modeler/Animator 2 | 40h |
| 360 | 12.3.5.3 | Miscellaneous | 2d | 2001-03-08 | 2001-03-09 | 359 | 14d |  | Modeler/Animator 2 | 16h |
| 361 | 12.3.6 | **Unit Model (Warlocks)** | 10d | 2001-03-12 | 2001-03-23 | 357 | 14d | 0d |  | 80h |
| 362 | 12.3.6.1 | Low-Poly Model | 3d | 2001-03-12 | 2001-03-14 |  | 14d | 0d | Modeler/Animator 2 | 24h |
| 363 | 12.3.6.2 | Animation | 5d | 2001-03-15 | 2001-03-21 | 362 | 14d | 0d | Modeler/Animator 2 | 40h |
| 364 | 12.3.6.3 | Miscellaneous | 2d | 2001-03-22 | 2001-03-23 | 363 | 14d |  | Modeler/Animator 2 | 16h |
| 365 | 12.3.7 | **Unit Model (Ghol)** | 10d | 2001-03-26 | 2001-04-06 | 361 | 14d | 0d |  | 80h |
| 366 | 12.3.7.1 | Low-Poly Model | 3d | 2001-03-26 | 2001-03-28 |  | 14d | 0d | Modeler/Animator 2 | 24h |
| 367 | 12.3.7.2 | Animation | 5d | 2001-03-29 | 2001-04-04 | 366 | 14d | 0d | Modeler/Animator 2 | 40h |
| 368 | 12.3.7.3 | Miscellaneous | 2d | 2001-04-05 | 2001-04-06 | 367 | 14d |  | Modeler/Animator 2 | 16h |
| 369 | 12.3.8 | **Unit Model (Myrkridian Pack-Mage)** | 10d | 2001-04-09 | 2001-04-20 | 365 | 14d | 0d |  | 80h |
| 370 | 12.3.8.1 | Low-Poly Model | 3d | 2001-04-09 | 2001-04-11 |  | 14d | 0d | Modeler/Animator 2 | 24h |
| 371 | 12.3.8.2 | Animation | 5d | 2001-04-12 | 2001-04-18 | 370 | 14d | 0d | Modeler/Animator 2 | 40h |
| 372 | 12.3.8.3 | Miscellaneous | 2d | 2001-04-19 | 2001-04-20 | 371 | 14d |  | Modeler/Animator 2 | 16h |

| ID | WBS | Task | Duration | Start | Finish | Predecessors | Total slack | Free slack | Resources | Work |
| --- | --- | --- | --- | --- | --- | --- | --- | --- | --- | --- |
| 373 | 12.3.9 | **Unit Model (Myrdred)** | 10d | 2001-04-23 | 2001-05-04 | 369 | 14d | 0d |  | 80h |
| 374 | 12.3.9.1 | Low-Poly Model | 3d | 2001-04-23 | 2001-04-25 |  | 14d | 0d | Modeler/Animator 2 | 24h |
| 375 | 12.3.9.2 | Animation | 5d | 2001-04-26 | 2001-05-02 | 374 | 14d | 0d | Modeler/Animator 2 | 40h |
| 376 | 12.3.9.3 | Miscellaneous | 2d | 2001-05-03 | 2001-05-04 | 375 | 14d |  | Modeler/Animator 2 | 16h |
| 377 | 12.3.10 | **Unit Model (Forgotten)** | 10d | 2001-05-07 | 2001-05-18 | 373 | 14d | 0d |  | 80h |
| 378 | 12.3.10.1 | Low-Poly Model | 3d | 2001-05-07 | 2001-05-09 |  | 14d | 0d | Modeler/Animator 2 | 24h |
| 379 | 12.3.10.2 | Animation | 5d | 2001-05-10 | 2001-05-16 | 378 | 14d | 0d | Modeler/Animator 2 | 40h |
| 380 | 12.3.10.3 | Miscellaneous | 2d | 2001-05-17 | 2001-05-18 | 379 | 14d |  | Modeler/Animator 2 | 16h |
| 381 | 12.3.11 | **Unit Model (Trow)** | 10d | 2001-05-21 | 2001-06-01 | 377 | 14d | 0d |  | 80h |
| 382 | 12.3.11.1 | Low-Poly Model | 3d | 2001-05-21 | 2001-05-23 |  | 14d | 0d | Modeler/Animator 2 | 24h |
| 383 | 12.3.11.2 | Animation | 5d | 2001-05-24 | 2001-05-30 | 382 | 14d | 0d | Modeler/Animator 2 | 40h |
| 384 | 12.3.11.3 | Miscellaneous | 2d | 2001-05-31 | 2001-06-01 | 383 | 14d |  | Modeler/Animator 2 | 16h |
| 385 | 12.3.12 | **Unit Model (Stygian Knight)** | 10d | 2001-06-04 | 2001-06-15 | 381 | 14d | 0d |  | 80h |
| 386 | 12.3.12.1 | Low-Poly Model | 3d | 2001-06-04 | 2001-06-06 |  | 14d | 0d | Modeler/Animator 2 | 24h |
| 387 | 12.3.12.2 | Animation | 5d | 2001-06-07 | 2001-06-13 | 386 | 14d | 0d | Modeler/Animator 2 | 40h |
| 388 | 12.3.12.3 | Miscellaneous | 2d | 2001-06-14 | 2001-06-15 | 387 | 14d |  | Modeler/Animator 2 | 16h |
| 389 | 12.3.13 | **Unit Model (Avatara)** | 10d | 2001-06-18 | 2001-06-29 | 385 | 14d | 0d |  | 80h |
| 390 | 12.3.13.1 | Low-Poly Model | 3d | 2001-06-18 | 2001-06-20 |  | 14d | 0d | Modeler/Animator 2 | 24h |
| 391 | 12.3.13.2 | Animation | 5d | 2001-06-21 | 2001-06-27 | 390 | 14d | 0d | Modeler/Animator 2 | 40h |
| 392 | 12.3.13.3 | Miscellaneous | 2d | 2001-06-28 | 2001-06-29 | 391 | 14d |  | Modeler/Animator 2 | 16h |
| 393 | 12.3.14 | **Unit Model (Mjarin)** | 10d | 2001-07-02 | 2001-07-13 | 389 | 14d | 0d |  | 80h |
| 394 | 12.3.14.1 | Low-Poly Model | 3d | 2001-07-02 | 2001-07-04 |  | 14d | 0d | Modeler/Animator 2 | 24h |
| 395 | 12.3.14.2 | Animation | 5d | 2001-07-05 | 2001-07-11 | 394 | 14d | 0d | Modeler/Animator 2 | 40h |
| 396 | 12.3.14.3 | Miscellaneous | 2d | 2001-07-12 | 2001-07-13 | 395 | 14d |  | Modeler/Animator 2 | 16h |

| ID | WBS | Task | Duration | Start | Finish | Predecessors | Total slack | Free slack | Constraint | Resources | Work |
| --- | --- | --- | --- | --- | --- | --- | --- | --- | --- | --- | --- |
| 397 | 12.3.15 | **Unit Model (Spiders)** | 10d | 2001-07-16 | 2001-07-27 | 393 | 14d | 0d |  |  | 80h |
| 398 | 12.3.15.1 | Low-Poly Model | 3d | 2001-07-16 | 2001-07-18 |  | 14d | 0d |  | Modeler/Animator 2 | 24h |
| 399 | 12.3.15.2 | Animation | 5d | 2001-07-19 | 2001-07-25 | 398 | 14d | 0d |  | Modeler/Animator 2 | 40h |
| 400 | 12.3.15.3 | Miscellaneous | 2d | 2001-07-26 | 2001-07-27 | 399 | 14d |  |  | Modeler/Animator 2 | 16h |
| 401 | 12.3.16 | **Unit Model (Syrkrosh)** | 10d | 2001-07-30 | 2001-08-10 | 397 | 14d | 0d |  |  | 80h |
| 402 | 12.3.16.1 | Low-Poly Model | 3d | 2001-07-30 | 2001-08-01 |  | 14d | 0d |  | Modeler/Animator 2 | 24h |
| 403 | 12.3.16.2 | Animation | 5d | 2001-08-02 | 2001-08-08 | 402 | 14d | 0d |  | Modeler/Animator 2 | 40h |
| 404 | 12.3.16.3 | Miscellaneous | 2d | 2001-08-09 | 2001-08-10 | 403 | 14d |  |  | Modeler/Animator 2 | 16h |
| 405 | 12.3.17 | **Unit Model (Chicken / Pig)** | 10d | 2001-08-13 | 2001-08-24 | 401 | 14d | 0d |  |  | 80h |
| 406 | 12.3.17.1 | Low-Poly Model | 3d | 2001-08-13 | 2001-08-15 |  | 14d | 0d |  | Modeler/Animator 2 | 24h |
| 407 | 12.3.17.2 | Animation | 5d | 2001-08-16 | 2001-08-22 | 406 | 14d | 0d |  | Modeler/Animator 2 | 40h |
| 408 | 12.3.17.3 | Miscellaneous | 2d | 2001-08-23 | 2001-08-24 | 407 | 14d |  |  | Modeler/Animator 2 | 16h |
| 409 | 12.3.18 | Touch-up | 5.2w | 2001-08-27 | 2001-09-28 | 405 | 14d |  | start no earlier than 2001-08-27 | Modeler/Animator 2 | 208h |
| 410 | 12.4 | **TEXTURER 1** | 196d | 2001-01-01 | 2001-09-28 |  | 14d |  |  |  | 1560h |
| 411 | 12.4.1 | Concept Art | 1w | 2001-01-01 | 2001-01-05 |  | 200d | 0d |  | Texturer 1 | 40h |
| 412 | 12.4.2 | **Model Textures** | 176d | 2001-01-08 | 2001-09-07 | 411 | 29d |  |  |  | 840h |
| 413 | 12.4.2.1 | Model Texture (Archer) | 1w | 2001-01-08 | 2001-01-12 |  | 200d |  |  | Texturer 1 | 40h |
| 414 | 12.4.2.2 | Model Texture (Berserk) | 1w | 2001-01-22 | 2001-01-26 |  | 190d |  | start no earlier than 2001-01-21 | Texturer 1 | 40h |
| 415 | 12.4.2.3 | Model Texture (Thrall) | 1w | 2001-02-05 | 2001-02-09 |  | 180d |  | start no earlier than 2001-02-04 | Texturer 1 | 40h |
| 416 | 12.4.2.4 | Model Texture (Spearmenl) | 1w | 2001-02-19 | 2001-02-23 |  | 170d |  | start no earlier than 2001-02-18 | Texturer 1 | 40h |
| 417 | 12.4.2.5 | Model Texture (Warlocks) | 1w | 2001-03-05 | 2001-03-09 |  | 160d |  | start no earlier than 2001-03-04 | Texturer 1 | 40h |
| 418 | 12.4.2.6 | Model Texture (Dwarven Demolitionist) | 1w | 2001-03-19 | 2001-03-23 |  | 150d |  | start no earlier than 2001-03-18 | Texturer 1 | 40h |
| 419 | 12.4.2.7 | Model Texture (Connacht) | 1w | 2001-04-02 | 2001-04-06 |  | 140d |  | start no earlier than 2001-04-01 | Texturer 1 | 40h |
| 420 | 12.4.2.8 | Model Texture (Damas) | 1w | 2001-04-16 | 2001-04-20 |  | 130d |  | start no earlier than 2001-04-15 | Texturer 1 | 40h |
| 421 | 12.4.2.9 | Model Texture (Trow Iron Warrior) | 1w | 2001-04-30 | 2001-05-04 |  | 120d |  | start no earlier than 2001-04-29 | Texturer 1 | 40h |
| 422 | 12.4.2.10 | Model Texture (Oghre) | 1w | 2001-05-14 | 2001-05-18 |  | 110d |  | start no earlier than 2001-05-13 | Texturer 1 | 40h |
| 423 | 12.4.2.11 | Model Texture (Ravanna) | 1w | 2001-05-28 | 2001-06-01 |  | 100d |  | start no earlier than 2001-05-27 | Texturer 1 | 40h |
| 424 | 12.4.2.12 | Model Texture (Dwarven Axe-Warriors) | 1w | 2001-06-11 | 2001-06-15 |  | 90d |  | start no earlier than 2001-06-10 | Texturer 1 | 40h |
| 425 | 12.4.2.13 | Model Texture (Dwarven Smiths) | 1w | 2001-06-25 | 2001-06-29 |  | 80d |  | start no earlier than 2001-06-24 | Texturer 1 | 40h |
| 426 | 12.4.2.14 | Model Texture (Mazzarin) | 1w | 2001-07-09 | 2001-07-13 |  | 70d |  | start no earlier than 2001-07-08 | Texturer 1 | 40h |
| 427 | 12.4.2.15 | Model Texture (Stygian Knight) | 1w | 2001-07-23 | 2001-07-27 |  | 60d |  | start no earlier than 2001-07-22 | Texturer 1 | 40h |
| 428 | 12.4.2.16 | Model Texture (Moagim Reborn) | 1w | 2001-07-30 | 2001-08-03 |  | 55d |  | start no earlier than 2001-07-29 | Texturer 1 | 40h |
| 429 | 12.4.2.17 | Model Texture (Emperor Leitrim) | 1w | 2001-08-06 | 2001-08-10 |  | 50d |  | start no earlier than 2001-08-05 | Texturer 1 | 40h |
| 430 | 12.4.2.18 | Model Texture (Spider Cultists) | 1w | 2001-08-13 | 2001-08-17 |  | 45d |  | start no earlier than 2001-08-12 | Texturer 1 | 40h |
| 431 | 12.4.2.19 | Model Texture (Deer) | 1w | 2001-08-20 | 2001-08-24 |  | 40d |  | start no earlier than 2001-08-19 | Texturer 1 | 40h |
| 432 | 12.4.2.20 | Model Texture (Springal) | 1w | 2001-08-27 | 2001-08-31 |  | 35d |  | start no earlier than 2001-08-26 | Texturer 1 | 40h |
| 433 | 12.4.2.21 | Model Texture (Hawk) | 1w | 2001-09-03 | 2001-09-07 |  | 29d |  | start no earlier than 2001-09-02 | Texturer 1 | 40h |

| ID | WBS | Task | Duration | Start | Finish | Total slack | Constraint | Resources | Work |
| --- | --- | --- | --- | --- | --- | --- | --- | --- | --- |
| 434 | 12.4.3 | **Level Terrain Maps** | 135d | 2001-01-15 | 2001-07-20 | 65d |  |  | 560h |
| 435 | 12.4.3.1 | Level Terrain (19-Children of Bahl'al) | 1w | 2001-01-15 | 2001-01-19 | 195d | start no earlier than 2001-01-15 | Texturer 1 | 40h |
| 436 | 12.4.3.2 | Level Terrain (8-Road to Myrgard) | 1w | 2001-01-29 | 2001-02-02 | 185d | start no earlier than 2001-01-29 | Texturer 1 | 40h |
| 437 | 12.4.3.3 | Level Terrain (2-The Nest) | 1w | 2001-02-12 | 2001-02-16 | 175d | start no earlier than 2001-02-12 | Texturer 1 | 40h |
| 438 | 12.4.3.4 | Level Terrain (4-The Pack-Mage) | 1w | 2001-02-26 | 2001-03-02 | 165d | start no earlier than 2001-02-26 | Texturer 1 | 40h |
| 439 | 12.4.3.5 | Level Terrain (16-Refugees) | 1w | 2001-03-12 | 2001-03-16 | 155d | start no earlier than 2001-03-12 | Texturer 1 | 40h |
| 440 | 12.4.3.6 | Level Terrain (1-Defense of Yursgrad) | 1w | 2001-03-26 | 2001-03-30 | 145d | start no earlier than 2001-03-26 | Texturer 1 | 40h |
| 441 | 12.4.3.7 | Level Terrain (13-Rod of the Callieach) | 1w | 2001-04-09 | 2001-04-13 | 135d | start no earlier than 2001-04-09 | Texturer 1 | 40h |
| 442 | 12.4.3.8 | Level Terrain (10-Imprisonment) | 1w | 2001-04-23 | 2001-04-27 | 125d | start no earlier than 2001-04-23 | Texturer 1 | 40h |
| 443 | 12.4.3.9 | Level Terrain (12-Siege of Llancarfan) | 1w | 2001-05-07 | 2001-05-11 | 115d | start no earlier than 2001-05-07 | Texturer 1 | 40h |
| 444 | 12.4.3.10 | Level Terrain (6-Forgotten Lands) | 1w | 2001-05-21 | 2001-05-25 | 105d | start no earlier than 2001-05-21 | Texturer 1 | 40h |
| 445 | 12.4.3.11 | Level Terrain (17-Smith's Forge) | 1w | 2001-06-04 | 2001-06-08 | 95d | start no earlier than 2001-06-04 | Texturer 1 | 40h |
| 446 | 12.4.3.12 | Level Terrain (20-Sunhammer) | 1w | 2001-06-18 | 2001-06-22 | 85d | start no earlier than 2001-06-18 | Texturer 1 | 40h |
| 447 | 12.4.3.13 | Level Terrain (21-Heartstone of Nyx) | 1w | 2001-07-02 | 2001-07-06 | 75d | start no earlier than 2001-07-02 | Texturer 1 | 40h |
| 448 | 12.4.3.14 | Level Terrain (24-Vengeance) | 1w | 2001-07-16 | 2001-07-20 | 65d | start no earlier than 2001-07-16 | Texturer 1 | 40h |
| 449 | 12.4.4 | Touch-up | 3w | 2001-09-10 | 2001-09-28 | 14d | start no earlier than 2001-09-10 | Texturer 1 | 120h |
| 450 | 12.5 | **TEXTURER 2** | 196d | 2001-01-01 | 2001-09-28 | 14d |  |  | 1560h |
| 451 | 12.5.1 | **Interface** | 85d | 2001-01-01 | 2001-04-27 | 125d |  |  | 360h |
| 452 | 12.5.1.1 | Interface (Main Game Screen) | 5d | 2001-01-01 | 2001-01-05 | 205d |  | Texturer 2 | 40h |
| 453 | 12.5.1.2 | Interface (New Game Screen) | 5d | 2001-01-15 | 2001-01-19 | 195d | start no earlier than 2001-01-15 | Texturer 2 | 40h |
| 454 | 12.5.1.3 | Interface (Load Game Screen) | 5d | 2001-01-29 | 2001-02-02 | 185d | start no earlier than 2001-01-29 | Texturer 2 | 40h |
| 455 | 12.5.1.4 | Interface (Films Screen) | 5d | 2001-02-12 | 2001-02-16 | 175d | start no earlier than 2001-02-12 | Texturer 2 | 40h |
| 456 | 12.5.1.5 | Interface (Options Screen) | 5d | 2001-02-26 | 2001-03-02 | 165d | start no earlier than 2001-02-26 | Texturer 2 | 40h |
| 457 | 12.5.1.6 | Interface (Options Screens) | 5d | 2001-03-12 | 2001-03-16 | 155d | start no earlier than 2001-03-12 | Texturer 2 | 40h |
| 458 | 12.5.1.7 | Interface (Multiplay Screens) | 5d | 2001-03-26 | 2001-03-30 | 145d | start no earlier than 2001-03-26 | Texturer 2 | 40h |
| 459 | 12.5.1.8 | Interface (Cutscene Screens) | 5d | 2001-04-09 | 2001-04-13 | 135d | start no earlier than 2001-04-09 | Texturer 2 | 40h |
| 460 | 12.5.1.9 | Interface (Network Screens) | 5d | 2001-04-23 | 2001-04-27 | 125d | start no earlier than 2001-04-23 | Texturer 2 | 40h |

| ID | WBS | Task | Duration | Start | Finish | Total slack | Constraint | Resources | Work |
| --- | --- | --- | --- | --- | --- | --- | --- | --- | --- |
| 461 | 12.5.2 | **Model Textures** | 170d | 2001-01-08 | 2001-08-31 | 35d |  |  | 840h |
| 462 | 12.5.2.1 | Model Texture (Soldier) | 5d | 2001-01-08 | 2001-01-12 | 200d | start no earlier than 2001-01-07 | Texturer 2 | 40h |
| 463 | 12.5.2.2 | Model Texture (Myrkridia) | 5d | 2001-01-22 | 2001-01-26 | 190d | start no earlier than 2001-01-22 | Texturer 2 | 40h |
| 464 | 12.5.2.3 | Model Texture (Soulless) | 5d | 2001-02-05 | 2001-02-09 | 180d | start no earlier than 2001-02-05 | Texturer 2 | 40h |
| 465 | 12.5.2.4 | Model Texture (Wights) | 5d | 2001-02-19 | 2001-02-23 | 170d | start no earlier than 2001-02-18 | Texturer 2 | 40h |
| 466 | 12.5.2.5 | Model Texture (Ghol) | 5d | 2001-03-05 | 2001-03-09 | 160d | start no earlier than 2001-03-04 | Texturer 2 | 40h |
| 467 | 12.5.2.6 | Model Texture (More Ghol) | 5d | 2001-03-19 | 2001-03-23 | 150d | start no earlier than 2001-03-18 | Texturer 2 | 40h |
| 468 | 12.5.2.7 | Model Texture (Peasants) | 5d | 2001-04-02 | 2001-04-06 | 140d | start no earlier than 2001-04-01 | Texturer 2 | 40h |
| 469 | 12.5.2.8 | Model Texture (Heron Guard) | 5d | 2001-04-16 | 2001-04-20 | 130d | start no earlier than 2001-04-15 | Texturer 2 | 40h |
| 470 | 12.5.2.9 | Model Texture (Myrkridian Giant) | 5d | 2001-04-30 | 2001-05-04 | 120d | start no earlier than 2001-04-29 | Texturer 2 | 40h |
| 471 | 12.5.2.10 | Model Texture (Myrkridian Pack-Mage) | 5d | 2001-05-14 | 2001-05-18 | 110d | start no earlier than 2001-05-13 | Texturer 2 | 40h |
| 472 | 12.5.2.11 | Model Texture (Myrdred) | 5d | 2001-05-28 | 2001-06-01 | 100d | start no earlier than 2001-05-27 | Texturer 2 | 40h |
| 473 | 12.5.2.12 | Model Texture (Forgotten) | 5d | 2001-06-11 | 2001-06-15 | 90d | start no earlier than 2001-06-10 | Texturer 2 | 40h |
| 474 | 12.5.2.13 | Model Texture (Trow) | 5d | 2001-06-25 | 2001-06-29 | 80d | start no earlier than 2001-06-24 | Texturer 2 | 40h |
| 475 | 12.5.2.14 | Model Texture (Mahir) | 5d | 2001-07-09 | 2001-07-13 | 70d | start no earlier than 2001-07-08 | Texturer 2 | 40h |
| 476 | 12.5.2.15 | Model Texture (Avatara) | 5d | 2001-07-16 | 2001-07-20 | 65d | start no earlier than 2001-07-16 | Texturer 2 | 40h |
| 477 | 12.5.2.16 | Model Texture (The Watcher) | 5d | 2001-07-23 | 2001-07-27 | 60d | start no earlier than 2001-07-23 | Texturer 2 | 40h |
| 478 | 12.5.2.17 | Model Texture (Mjarin) | 5d | 2001-07-30 | 2001-08-03 | 55d | start no earlier than 2001-07-30 | Texturer 2 | 40h |
| 479 | 12.5.2.18 | Model Texture (Spiders) | 5d | 2001-08-06 | 2001-08-10 | 50d | start no earlier than 2001-08-05 | Texturer 2 | 40h |
| 480 | 12.5.2.19 | Model Texture (Syrkrosh) | 5d | 2001-08-13 | 2001-08-17 | 45d | start no earlier than 2001-08-12 | Texturer 2 | 40h |
| 481 | 12.5.2.20 | Model Texture (Chicken) | 5d | 2001-08-20 | 2001-08-24 | 40d | start no earlier than 2001-08-19 | Texturer 2 | 40h |
| 482 | 12.5.2.21 | Model Texture (Pig) | 5d | 2001-08-27 | 2001-08-31 | 35d | start no earlier than 2001-08-26 | Texturer 2 | 40h |
| 483 | 12.5.3 | **Scenery Models** | 35d | 2001-05-07 | 2001-06-22 | 85d |  |  | 160h |
| 484 | 12.5.3.1 | Scenery Models | 5d | 2001-05-07 | 2001-05-11 | 115d | start no earlier than 2001-05-07 | Texturer 2 | 40h |
| 485 | 12.5.3.2 | Scenery Models | 5d | 2001-05-21 | 2001-05-25 | 105d | start no earlier than 2001-05-20 | Texturer 2 | 40h |
| 486 | 12.5.3.3 | Scenery Models | 5d | 2001-06-04 | 2001-06-08 | 95d | start no earlier than 2001-06-03 | Texturer 2 | 40h |
| 487 | 12.5.3.4 | Scenery Models | 5d | 2001-06-18 | 2001-06-22 | 85d | start no earlier than 2001-06-17 | Texturer 2 | 40h |
| 488 | 12.5.4 | Level Terrain (Cutscene-Imperial Chambers) | 5d | 2001-07-02 | 2001-07-06 | 75d | start no earlier than 2001-07-01 | Texturer 2 | 40h |
| 489 | 12.5.5 | Touch-up | 4w | 2001-09-03 | 2001-09-28 | 14d | start no earlier than 2001-09-03 | Texturer 2 | 160h |

| ID | WBS | Task | Duration | Start | Finish | Predecessors | Total slack | Free slack | Constraint | Resources | Work |
| --- | --- | --- | --- | --- | --- | --- | --- | --- | --- | --- | --- |
| 490 | 12.6 | **ASSISTANT ARTIST** | 195d | 2001-01-01 | 2001-09-27 |  | 15d |  |  |  | 1560h |
| 491 | 12.6.1 | Scenery Models | 13w | 2001-01-01 | 2001-03-30 |  | 145d |  |  | Assistant Artist | 520h |
| 492 | 12.6.2 | Intro Movie | 8w | 2001-04-02 | 2001-05-25 | 647 | 65d | 25d | start no earlier than 2001-02-04 | Assistant Artist | 320h |
| 493 | 12.6.3 | Credits Movie | 4w | 2001-05-28 | 2001-06-22 |  | 75d | 25d | start no earlier than 2001-05-27 | Assistant Artist | 160h |
| 494 | 12.6.4 | Mini-Map Pictures | 8w | 2001-06-25 | 2001-08-17 |  | 45d |  | start no earlier than 2001-06-24 | Assistant Artist | 320h |
| 495 | 12.6.5 | Act Screens | 1w | 2001-08-20 | 2001-08-24 |  | 40d |  | start no earlier than 2001-08-19 | Assistant Artist | 40h |
| 496 | 12.6.6 | Touch-up | 5w | 2001-08-27 | 2001-09-27 |  | 15d |  | start no earlier than 2001-08-26 | Assistant Artist | 200h |
| 497 | 13 | **OUT-OF-HOUSE ART ASSETS** | 132d | 2001-02-05 | 2001-08-07 |  | 53d |  |  |  | 3168h |
| 498 | 13.1 | **LEVEL SKETCHES 1** | 132d | 2001-02-05 | 2001-08-07 |  | 53d |  |  |  | 1056h |
| 499 | 13.1.1 | Level Sketches 1 | 3d | 2001-02-05 | 2001-02-07 |  | 182d |  | start no earlier than 2001-02-05 | Sketch Artist 1 | 24h |
| 500 | 13.1.2 | Level Sketches 2 | 3d | 2001-02-08 | 2001-02-12 |  | 179d |  | start no earlier than 2001-02-08 | Sketch Artist 1 | 24h |
| 501 | 13.1.3 | Level Sketches 3 | 3d | 2001-02-13 | 2001-02-15 |  | 176d |  | start no earlier than 2001-02-13 | Sketch Artist 1 | 24h |
| 502 | 13.1.4 | Level Sketches 4 | 3d | 2001-02-16 | 2001-02-20 |  | 173d |  | start no earlier than 2001-02-16 | Sketch Artist 1 | 24h |
| 503 | 13.1.5 | Level Sketches 5 | 3d | 2001-02-21 | 2001-02-23 |  | 170d |  | start no earlier than 2001-02-21 | Sketch Artist 1 | 24h |
| 504 | 13.1.6 | Level Sketches 6 | 3d | 2001-02-26 | 2001-02-28 |  | 167d |  | start no earlier than 2001-02-26 | Sketch Artist 1 | 24h |
| 505 | 13.1.7 | Level Sketches 7 | 3d | 2001-03-01 | 2001-03-05 |  | 164d |  | start no earlier than 2001-03-01 | Sketch Artist 1 | 24h |
| 506 | 13.1.8 | Level Sketches 8 | 3d | 2001-03-06 | 2001-03-08 |  | 161d |  | start no earlier than 2001-03-06 | Sketch Artist 1 | 24h |
| 507 | 13.1.9 | Level Sketches 9 | 3d | 2001-03-09 | 2001-03-13 |  | 158d |  | start no earlier than 2001-03-09 | Sketch Artist 1 | 24h |
| 508 | 13.1.10 | Level Sketches 10 | 3d | 2001-03-14 | 2001-03-16 |  | 155d |  | start no earlier than 2001-03-14 | Sketch Artist 1 | 24h |
| 509 | 13.1.11 | Level Sketches 11 | 3d | 2001-03-19 | 2001-03-21 |  | 152d |  | start no earlier than 2001-03-19 | Sketch Artist 1 | 24h |
| 510 | 13.1.12 | Level Sketches 12 | 3d | 2001-03-22 | 2001-03-26 |  | 149d |  | start no earlier than 2001-03-22 | Sketch Artist 1 | 24h |
| 511 | 13.1.13 | Level Sketches 13 | 3d | 2001-03-27 | 2001-03-29 |  | 146d |  | start no earlier than 2001-03-27 | Sketch Artist 1 | 24h |
| 512 | 13.1.14 | Level Sketches 14 | 3d | 2001-03-30 | 2001-04-03 |  | 143d |  | start no earlier than 2001-03-30 | Sketch Artist 1 | 24h |
| 513 | 13.1.15 | Level Sketches 15 | 3d | 2001-04-04 | 2001-04-06 |  | 140d |  | start no earlier than 2001-04-04 | Sketch Artist 1 | 24h |
| 514 | 13.1.16 | Level Sketches 16 | 3d | 2001-04-09 | 2001-04-11 |  | 137d |  | start no earlier than 2001-04-09 | Sketch Artist 1 | 24h |
| 515 | 13.1.17 | Level Sketches 17 | 3d | 2001-04-12 | 2001-04-16 |  | 134d |  | start no earlier than 2001-04-12 | Sketch Artist 1 | 24h |
| 516 | 13.1.18 | Level Sketches 18 | 3d | 2001-04-17 | 2001-04-19 |  | 131d |  | start no earlier than 2001-04-17 | Sketch Artist 1 | 24h |
| 517 | 13.1.19 | Level Sketches 19 | 3d | 2001-04-20 | 2001-04-24 |  | 128d |  | start no earlier than 2001-04-20 | Sketch Artist 1 | 24h |
| 518 | 13.1.20 | Level Sketches 20 | 3d | 2001-04-25 | 2001-04-27 |  | 125d |  | start no earlier than 2001-04-25 | Sketch Artist 1 | 24h |
| 519 | 13.1.21 | Level Sketches 21 | 3d | 2001-04-30 | 2001-05-02 |  | 122d |  | start no earlier than 2001-04-30 | Sketch Artist 1 | 24h |
| 520 | 13.1.22 | Level Sketches 22 | 3d | 2001-05-03 | 2001-05-07 |  | 119d |  | start no earlier than 2001-05-03 | Sketch Artist 1 | 24h |
| 521 | 13.1.23 | Level Sketches 23 | 3d | 2001-05-08 | 2001-05-10 |  | 116d |  | start no earlier than 2001-05-08 | Sketch Artist 1 | 24h |
| 522 | 13.1.24 | Level Sketches 24 | 3d | 2001-05-11 | 2001-05-15 |  | 113d |  | start no earlier than 2001-05-11 | Sketch Artist 1 | 24h |
| 523 | 13.1.25 | Level Sketches 25 | 3d | 2001-05-16 | 2001-05-18 |  | 110d |  | start no earlier than 2001-05-16 | Sketch Artist 1 | 24h |
| 524 | 13.1.26 | Level Sketches 26 | 3d | 2001-05-21 | 2001-05-23 |  | 107d |  | start no earlier than 2001-05-21 | Sketch Artist 1 | 24h |
| 525 | 13.1.27 | Level Sketches 27 | 3d | 2001-05-24 | 2001-05-28 |  | 104d |  | start no earlier than 2001-05-24 | Sketch Artist 1 | 24h |
| 526 | 13.1.28 | Level Sketches 28 | 3d | 2001-05-29 | 2001-05-31 |  | 101d |  | start no earlier than 2001-05-29 | Sketch Artist 1 | 24h |
| 527 | 13.1.29 | Level Sketches 29 | 3d | 2001-06-01 | 2001-06-05 |  | 98d |  | start no earlier than 2001-06-01 | Sketch Artist 1 | 24h |
| 528 | 13.1.30 | Level Sketches 30 | 3d | 2001-06-06 | 2001-06-08 |  | 95d |  | start no earlier than 2001-06-06 | Sketch Artist 1 | 24h |
| 529 | 13.1.31 | Level Sketches 31 | 3d | 2001-06-11 | 2001-06-13 |  | 92d |  | start no earlier than 2001-06-11 | Sketch Artist 1 | 24h |
| 530 | 13.1.32 | Level Sketches 32 | 3d | 2001-06-14 | 2001-06-18 |  | 89d |  | start no earlier than 2001-06-14 | Sketch Artist 1 | 24h |
| 531 | 13.1.33 | Level Sketches 33 | 3d | 2001-06-19 | 2001-06-21 |  | 86d |  | start no earlier than 2001-06-19 | Sketch Artist 1 | 24h |
| 532 | 13.1.34 | Level Sketches 34 | 3d | 2001-06-22 | 2001-06-26 |  | 83d |  | start no earlier than 2001-06-22 | Sketch Artist 1 | 24h |
| 533 | 13.1.35 | Level Sketches 35 | 3d | 2001-06-27 | 2001-06-29 |  | 80d |  | start no earlier than 2001-06-27 | Sketch Artist 1 | 24h |
| 534 | 13.1.36 | Level Sketches 36 | 3d | 2001-07-02 | 2001-07-04 |  | 77d |  | start no earlier than 2001-07-02 | Sketch Artist 1 | 24h |
| 535 | 13.1.37 | Level Sketches 37 | 3d | 2001-07-05 | 2001-07-09 |  | 74d |  | start no earlier than 2001-07-05 | Sketch Artist 1 | 24h |
| 536 | 13.1.38 | Level Sketches 38 | 3d | 2001-07-10 | 2001-07-12 |  | 71d |  | start no earlier than 2001-07-10 | Sketch Artist 1 | 24h |
| 537 | 13.1.39 | Level Sketches 39 | 3d | 2001-07-13 | 2001-07-17 |  | 68d |  | start no earlier than 2001-07-13 | Sketch Artist 1 | 24h |
| 538 | 13.1.40 | Level Sketches 40 | 3d | 2001-07-18 | 2001-07-20 |  | 65d |  | start no earlier than 2001-07-18 | Sketch Artist 1 | 24h |
| 539 | 13.1.41 | Level Sketches 41 | 3d | 2001-07-23 | 2001-07-25 |  | 62d |  | start no earlier than 2001-07-23 | Sketch Artist 1 | 24h |
| 540 | 13.1.42 | Level Sketches 42 | 3d | 2001-07-26 | 2001-07-30 |  | 59d |  | start no earlier than 2001-07-26 | Sketch Artist 1 | 24h |
| 541 | 13.1.43 | Level Sketches 43 | 3d | 2001-07-31 | 2001-08-02 |  | 56d |  | start no earlier than 2001-07-31 | Sketch Artist 1 | 24h |
| 542 | 13.1.44 | Level Sketches 44 | 3d | 2001-08-03 | 2001-08-07 |  | 53d |  | start no earlier than 2001-08-03 | Sketch Artist 1 | 24h |

| ID | WBS | Task | Duration | Start | Finish | Total slack | Constraint | Resources | Work |
| --- | --- | --- | --- | --- | --- | --- | --- | --- | --- |
| 543 | 13.2 | **LEVEL SKETCHES 2** | 132d | 2001-02-05 | 2001-08-07 | 53d |  |  | 1056h |
| 544 | 13.2.1 | Level Sketches 1 | 3d | 2001-02-05 | 2001-02-07 | 182d | start no earlier than 2001-02-05 | Sketch Artist 2 | 24h |
| 545 | 13.2.2 | Level Sketches 2 | 3d | 2001-02-08 | 2001-02-12 | 179d | start no earlier than 2001-02-08 | Sketch Artist 2 | 24h |
| 546 | 13.2.3 | Level Sketches 3 | 3d | 2001-02-13 | 2001-02-15 | 176d | start no earlier than 2001-02-13 | Sketch Artist 2 | 24h |
| 547 | 13.2.4 | Level Sketches 4 | 3d | 2001-02-16 | 2001-02-20 | 173d | start no earlier than 2001-02-16 | Sketch Artist 2 | 24h |
| 548 | 13.2.5 | Level Sketches 5 | 3d | 2001-02-21 | 2001-02-23 | 170d | start no earlier than 2001-02-21 | Sketch Artist 2 | 24h |
| 549 | 13.2.6 | Level Sketches 6 | 3d | 2001-02-26 | 2001-02-28 | 167d | start no earlier than 2001-02-26 | Sketch Artist 2 | 24h |
| 550 | 13.2.7 | Level Sketches 7 | 3d | 2001-03-01 | 2001-03-05 | 164d | start no earlier than 2001-03-01 | Sketch Artist 2 | 24h |
| 551 | 13.2.8 | Level Sketches 8 | 3d | 2001-03-06 | 2001-03-08 | 161d | start no earlier than 2001-03-06 | Sketch Artist 2 | 24h |
| 552 | 13.2.9 | Level Sketches 9 | 3d | 2001-03-09 | 2001-03-13 | 158d | start no earlier than 2001-03-09 | Sketch Artist 2 | 24h |
| 553 | 13.2.10 | Level Sketches 10 | 3d | 2001-03-14 | 2001-03-16 | 155d | start no earlier than 2001-03-14 | Sketch Artist 2 | 24h |
| 554 | 13.2.11 | Level Sketches 11 | 3d | 2001-03-19 | 2001-03-21 | 152d | start no earlier than 2001-03-19 | Sketch Artist 2 | 24h |
| 555 | 13.2.12 | Level Sketches 12 | 3d | 2001-03-22 | 2001-03-26 | 149d | start no earlier than 2001-03-22 | Sketch Artist 2 | 24h |
| 556 | 13.2.13 | Level Sketches 13 | 3d | 2001-03-27 | 2001-03-29 | 146d | start no earlier than 2001-03-27 | Sketch Artist 2 | 24h |
| 557 | 13.2.14 | Level Sketches 14 | 3d | 2001-03-30 | 2001-04-03 | 143d | start no earlier than 2001-03-30 | Sketch Artist 2 | 24h |
| 558 | 13.2.15 | Level Sketches 15 | 3d | 2001-04-04 | 2001-04-06 | 140d | start no earlier than 2001-04-04 | Sketch Artist 2 | 24h |
| 559 | 13.2.16 | Level Sketches 16 | 3d | 2001-04-09 | 2001-04-11 | 137d | start no earlier than 2001-04-09 | Sketch Artist 2 | 24h |
| 560 | 13.2.17 | Level Sketches 17 | 3d | 2001-04-12 | 2001-04-16 | 134d | start no earlier than 2001-04-12 | Sketch Artist 2 | 24h |
| 561 | 13.2.18 | Level Sketches 18 | 3d | 2001-04-17 | 2001-04-19 | 131d | start no earlier than 2001-04-17 | Sketch Artist 2 | 24h |
| 562 | 13.2.19 | Level Sketches 19 | 3d | 2001-04-20 | 2001-04-24 | 128d | start no earlier than 2001-04-20 | Sketch Artist 2 | 24h |
| 563 | 13.2.20 | Level Sketches 20 | 3d | 2001-04-25 | 2001-04-27 | 125d | start no earlier than 2001-04-25 | Sketch Artist 2 | 24h |
| 564 | 13.2.21 | Level Sketches 21 | 3d | 2001-04-30 | 2001-05-02 | 122d | start no earlier than 2001-04-30 | Sketch Artist 2 | 24h |
| 565 | 13.2.22 | Level Sketches 22 | 3d | 2001-05-03 | 2001-05-07 | 119d | start no earlier than 2001-05-03 | Sketch Artist 2 | 24h |
| 566 | 13.2.23 | Level Sketches 23 | 3d | 2001-05-08 | 2001-05-10 | 116d | start no earlier than 2001-05-08 | Sketch Artist 2 | 24h |
| 567 | 13.2.24 | Level Sketches 24 | 3d | 2001-05-11 | 2001-05-15 | 113d | start no earlier than 2001-05-11 | Sketch Artist 2 | 24h |
| 568 | 13.2.25 | Level Sketches 25 | 3d | 2001-05-16 | 2001-05-18 | 110d | start no earlier than 2001-05-16 | Sketch Artist 2 | 24h |
| 569 | 13.2.26 | Level Sketches 26 | 3d | 2001-05-21 | 2001-05-23 | 107d | start no earlier than 2001-05-21 | Sketch Artist 2 | 24h |
| 570 | 13.2.27 | Level Sketches 27 | 3d | 2001-05-24 | 2001-05-28 | 104d | start no earlier than 2001-05-24 | Sketch Artist 2 | 24h |
| 571 | 13.2.28 | Level Sketches 28 | 3d | 2001-05-29 | 2001-05-31 | 101d | start no earlier than 2001-05-29 | Sketch Artist 2 | 24h |
| 572 | 13.2.29 | Level Sketches 29 | 3d | 2001-06-01 | 2001-06-05 | 98d | start no earlier than 2001-06-01 | Sketch Artist 2 | 24h |
| 573 | 13.2.30 | Level Sketches 30 | 3d | 2001-06-06 | 2001-06-08 | 95d | start no earlier than 2001-06-06 | Sketch Artist 2 | 24h |
| 574 | 13.2.31 | Level Sketches 31 | 3d | 2001-06-11 | 2001-06-13 | 92d | start no earlier than 2001-06-11 | Sketch Artist 2 | 24h |
| 575 | 13.2.32 | Level Sketches 32 | 3d | 2001-06-14 | 2001-06-18 | 89d | start no earlier than 2001-06-14 | Sketch Artist 2 | 24h |
| 576 | 13.2.33 | Level Sketches 33 | 3d | 2001-06-19 | 2001-06-21 | 86d | start no earlier than 2001-06-19 | Sketch Artist 2 | 24h |
| 577 | 13.2.34 | Level Sketches 34 | 3d | 2001-06-22 | 2001-06-26 | 83d | start no earlier than 2001-06-22 | Sketch Artist 2 | 24h |
| 578 | 13.2.35 | Level Sketches 35 | 3d | 2001-06-27 | 2001-06-29 | 80d | start no earlier than 2001-06-27 | Sketch Artist 2 | 24h |
| 579 | 13.2.36 | Level Sketches 36 | 3d | 2001-07-02 | 2001-07-04 | 77d | start no earlier than 2001-07-02 | Sketch Artist 2 | 24h |
| 580 | 13.2.37 | Level Sketches 37 | 3d | 2001-07-05 | 2001-07-09 | 74d | start no earlier than 2001-07-05 | Sketch Artist 2 | 24h |
| 581 | 13.2.38 | Level Sketches 38 | 3d | 2001-07-10 | 2001-07-12 | 71d | start no earlier than 2001-07-10 | Sketch Artist 2 | 24h |
| 582 | 13.2.39 | Level Sketches 39 | 3d | 2001-07-13 | 2001-07-17 | 68d | start no earlier than 2001-07-13 | Sketch Artist 2 | 24h |
| 583 | 13.2.40 | Level Sketches 40 | 3d | 2001-07-18 | 2001-07-20 | 65d | start no earlier than 2001-07-18 | Sketch Artist 2 | 24h |
| 584 | 13.2.41 | Level Sketches 41 | 3d | 2001-07-23 | 2001-07-25 | 62d | start no earlier than 2001-07-23 | Sketch Artist 2 | 24h |
| 585 | 13.2.42 | Level Sketches 42 | 3d | 2001-07-26 | 2001-07-30 | 59d | start no earlier than 2001-07-26 | Sketch Artist 2 | 24h |
| 586 | 13.2.43 | Level Sketches 43 | 3d | 2001-07-31 | 2001-08-02 | 56d | start no earlier than 2001-07-31 | Sketch Artist 2 | 24h |
| 587 | 13.2.44 | Level Sketches 44 | 3d | 2001-08-03 | 2001-08-07 | 53d | start no earlier than 2001-08-03 | Sketch Artist 2 | 24h |

| ID | WBS | Task | Duration | Start | Finish | Total slack | Constraint | Resources | Work |
| --- | --- | --- | --- | --- | --- | --- | --- | --- | --- |
| 588 | 13.3 | **LEVEL SKETCHES 3** | 132d | 2001-02-05 | 2001-08-07 | 53d |  |  | 1056h |
| 589 | 13.3.1 | Level Sketches 1 | 3d | 2001-02-05 | 2001-02-07 | 182d | start no earlier than 2001-02-05 | Sketch Artist 3 | 24h |
| 590 | 13.3.2 | Level Sketches 2 | 3d | 2001-02-08 | 2001-02-12 | 179d | start no earlier than 2001-02-08 | Sketch Artist 3 | 24h |
| 591 | 13.3.3 | Level Sketches 3 | 3d | 2001-02-13 | 2001-02-15 | 176d | start no earlier than 2001-02-13 | Sketch Artist 3 | 24h |
| 592 | 13.3.4 | Level Sketches 4 | 3d | 2001-02-16 | 2001-02-20 | 173d | start no earlier than 2001-02-16 | Sketch Artist 3 | 24h |
| 593 | 13.3.5 | Level Sketches 5 | 3d | 2001-02-21 | 2001-02-23 | 170d | start no earlier than 2001-02-21 | Sketch Artist 3 | 24h |
| 594 | 13.3.6 | Level Sketches 6 | 3d | 2001-02-26 | 2001-02-28 | 167d | start no earlier than 2001-02-26 | Sketch Artist 3 | 24h |
| 595 | 13.3.7 | Level Sketches 7 | 3d | 2001-03-01 | 2001-03-05 | 164d | start no earlier than 2001-03-01 | Sketch Artist 3 | 24h |
| 596 | 13.3.8 | Level Sketches 8 | 3d | 2001-03-06 | 2001-03-08 | 161d | start no earlier than 2001-03-06 | Sketch Artist 3 | 24h |
| 597 | 13.3.9 | Level Sketches 9 | 3d | 2001-03-09 | 2001-03-13 | 158d | start no earlier than 2001-03-09 | Sketch Artist 3 | 24h |
| 598 | 13.3.10 | Level Sketches 10 | 3d | 2001-03-14 | 2001-03-16 | 155d | start no earlier than 2001-03-14 | Sketch Artist 3 | 24h |
| 599 | 13.3.11 | Level Sketches 11 | 3d | 2001-03-19 | 2001-03-21 | 152d | start no earlier than 2001-03-19 | Sketch Artist 3 | 24h |
| 600 | 13.3.12 | Level Sketches 12 | 3d | 2001-03-22 | 2001-03-26 | 149d | start no earlier than 2001-03-22 | Sketch Artist 3 | 24h |
| 601 | 13.3.13 | Level Sketches 13 | 3d | 2001-03-27 | 2001-03-29 | 146d | start no earlier than 2001-03-27 | Sketch Artist 3 | 24h |
| 602 | 13.3.14 | Level Sketches 14 | 3d | 2001-03-30 | 2001-04-03 | 143d | start no earlier than 2001-03-30 | Sketch Artist 3 | 24h |
| 603 | 13.3.15 | Level Sketches 15 | 3d | 2001-04-04 | 2001-04-06 | 140d | start no earlier than 2001-04-04 | Sketch Artist 3 | 24h |
| 604 | 13.3.16 | Level Sketches 16 | 3d | 2001-04-09 | 2001-04-11 | 137d | start no earlier than 2001-04-09 | Sketch Artist 3 | 24h |
| 605 | 13.3.17 | Level Sketches 17 | 3d | 2001-04-12 | 2001-04-16 | 134d | start no earlier than 2001-04-12 | Sketch Artist 3 | 24h |
| 606 | 13.3.18 | Level Sketches 18 | 3d | 2001-04-17 | 2001-04-19 | 131d | start no earlier than 2001-04-17 | Sketch Artist 3 | 24h |
| 607 | 13.3.19 | Level Sketches 19 | 3d | 2001-04-20 | 2001-04-24 | 128d | start no earlier than 2001-04-20 | Sketch Artist 3 | 24h |
| 608 | 13.3.20 | Level Sketches 20 | 3d | 2001-04-25 | 2001-04-27 | 125d | start no earlier than 2001-04-25 | Sketch Artist 3 | 24h |
| 609 | 13.3.21 | Level Sketches 21 | 3d | 2001-04-30 | 2001-05-02 | 122d | start no earlier than 2001-04-30 | Sketch Artist 3 | 24h |
| 610 | 13.3.22 | Level Sketches 22 | 3d | 2001-05-03 | 2001-05-07 | 119d | start no earlier than 2001-05-03 | Sketch Artist 3 | 24h |
| 611 | 13.3.23 | Level Sketches 23 | 3d | 2001-05-08 | 2001-05-10 | 116d | start no earlier than 2001-05-08 | Sketch Artist 3 | 24h |
| 612 | 13.3.24 | Level Sketches 24 | 3d | 2001-05-11 | 2001-05-15 | 113d | start no earlier than 2001-05-11 | Sketch Artist 3 | 24h |
| 613 | 13.3.25 | Level Sketches 25 | 3d | 2001-05-16 | 2001-05-18 | 110d | start no earlier than 2001-05-16 | Sketch Artist 3 | 24h |
| 614 | 13.3.26 | Level Sketches 26 | 3d | 2001-05-21 | 2001-05-23 | 107d | start no earlier than 2001-05-21 | Sketch Artist 3 | 24h |
| 615 | 13.3.27 | Level Sketches 27 | 3d | 2001-05-24 | 2001-05-28 | 104d | start no earlier than 2001-05-24 | Sketch Artist 3 | 24h |
| 616 | 13.3.28 | Level Sketches 28 | 3d | 2001-05-29 | 2001-05-31 | 101d | start no earlier than 2001-05-29 | Sketch Artist 3 | 24h |
| 617 | 13.3.29 | Level Sketches 29 | 3d | 2001-06-01 | 2001-06-05 | 98d | start no earlier than 2001-06-01 | Sketch Artist 3 | 24h |
| 618 | 13.3.30 | Level Sketches 30 | 3d | 2001-06-06 | 2001-06-08 | 95d | start no earlier than 2001-06-06 | Sketch Artist 3 | 24h |
| 619 | 13.3.31 | Level Sketches 31 | 3d | 2001-06-11 | 2001-06-13 | 92d | start no earlier than 2001-06-11 | Sketch Artist 3 | 24h |
| 620 | 13.3.32 | Level Sketches 32 | 3d | 2001-06-14 | 2001-06-18 | 89d | start no earlier than 2001-06-14 | Sketch Artist 3 | 24h |
| 621 | 13.3.33 | Level Sketches 33 | 3d | 2001-06-19 | 2001-06-21 | 86d | start no earlier than 2001-06-19 | Sketch Artist 3 | 24h |
| 622 | 13.3.34 | Level Sketches 34 | 3d | 2001-06-22 | 2001-06-26 | 83d | start no earlier than 2001-06-22 | Sketch Artist 3 | 24h |
| 623 | 13.3.35 | Level Sketches 35 | 3d | 2001-06-27 | 2001-06-29 | 80d | start no earlier than 2001-06-27 | Sketch Artist 3 | 24h |
| 624 | 13.3.36 | Level Sketches 36 | 3d | 2001-07-02 | 2001-07-04 | 77d | start no earlier than 2001-07-02 | Sketch Artist 3 | 24h |
| 625 | 13.3.37 | Level Sketches 37 | 3d | 2001-07-05 | 2001-07-09 | 74d | start no earlier than 2001-07-05 | Sketch Artist 3 | 24h |
| 626 | 13.3.38 | Level Sketches 38 | 3d | 2001-07-10 | 2001-07-12 | 71d | start no earlier than 2001-07-10 | Sketch Artist 3 | 24h |
| 627 | 13.3.39 | Level Sketches 39 | 3d | 2001-07-13 | 2001-07-17 | 68d | start no earlier than 2001-07-13 | Sketch Artist 3 | 24h |
| 628 | 13.3.40 | Level Sketches 40 | 3d | 2001-07-18 | 2001-07-20 | 65d | start no earlier than 2001-07-18 | Sketch Artist 3 | 24h |
| 629 | 13.3.41 | Level Sketches 41 | 3d | 2001-07-23 | 2001-07-25 | 62d | start no earlier than 2001-07-23 | Sketch Artist 3 | 24h |
| 630 | 13.3.42 | Level Sketches 42 | 3d | 2001-07-26 | 2001-07-30 | 59d | start no earlier than 2001-07-26 | Sketch Artist 3 | 24h |
| 631 | 13.3.43 | Level Sketches 43 | 3d | 2001-07-31 | 2001-08-02 | 56d | start no earlier than 2001-07-31 | Sketch Artist 3 | 24h |
| 632 | 13.3.44 | Level Sketches 44 | 3d | 2001-08-03 | 2001-08-07 | 53d | start no earlier than 2001-08-03 | Sketch Artist 3 | 24h |

| ID | WBS | Task | Duration | Start | Finish | Predecessors | Total slack | Free slack | Constraint | Resources | Work |
| --- | --- | --- | --- | --- | --- | --- | --- | --- | --- | --- | --- |
| 633 | 14 | **OUT-OF-HOUSE SOUND ASSETS** | 155d | 2001-01-22 | 2001-08-24 |  | 40d |  |  |  | 2400h |
| 634 | 14.1 | **MUSIC** | 145d | 2001-01-22 | 2001-08-10 |  | 50d |  |  |  | 1160h |
| 635 | 14.1.1 | Main Interface Music | 3w | 2001-01-22 | 2001-02-09 |  | 80d | 0d | start no earlier than 2001-01-21 | Out-of-House Music | 120h |
| 636 | 14.1.2 | 10 Level Music Scores | 10w | 2001-02-12 | 2001-04-20 | 635 | 80d | 0d |  | Out-of-House Music | 400h |
| 637 | 14.1.3 | 17 Music Score Re-Mixes | 10w | 2001-04-23 | 2001-06-29 | 636 | 80d |  |  | Out-of-House Music | 400h |
| 638 | 14.1.4 | Intro Movie Music | 4w | 2001-07-02 | 2001-07-27 | 492 | 40d | 0d | start no earlier than 2001-07-01 | Out-of-House Music | 160h |
| 639 | 14.1.5 | Credits Music | 2w | 2001-07-30 | 2001-08-10 | 493 | 50d |  | start no earlier than 2001-07-29 | Out-of-House Music | 80h |
| 640 | 14.2 | **SOUND EFFECTS** | 90d | 2001-04-23 | 2001-08-24 |  | 40d |  |  |  | 720h |
| 641 | 14.2.1 | New Unit Sounds | 8w | 2001-04-23 | 2001-06-15 |  | 60d | 0d | start no earlier than 2001-04-22 | Out-of-House Sound FX | 320h |
| 642 | 14.2.2 | New Spell Sounds | 3w | 2001-06-18 | 2001-07-06 | 641 | 60d | 0d |  | Out-of-House Sound FX | 120h |
| 643 | 14.2.3 | New Ambient Level Sounds | 2w | 2001-07-09 | 2001-07-20 | 642 | 60d | 0d |  | Out-of-House Sound FX | 80h |
| 644 | 14.2.4 | New Interface Sounds | 1w | 2001-07-23 | 2001-07-27 | 643 | 60d |  |  | Out-of-House Sound FX | 40h |
| 645 | 14.2.5 | Intro Movie SFX | 4w | 2001-07-30 | 2001-08-24 | 638 | 40d |  |  | Out-of-House Sound FX | 160h |
| 646 | 14.3 | **NARRATION** | 65d | 2001-03-26 | 2001-06-22 |  | 65d |  |  |  | 520h |
| 647 | 14.3.1 | Intro Movie Narration | 1w | 2001-03-26 | 2001-03-30 |  | 65d | 0d | start no earlier than 2001-03-25 | Out-of-House Narration | 40h |
| 648 | 14.3.2 | Level Narration (English) | 4w | 2001-04-02 | 2001-04-27 | 647 | 85d | 0d |  | Out-of-House Narration | 160h |
| 649 | 14.3.3 | Unit Voice Acting (English) | 8w | 2001-04-30 | 2001-06-22 | 648 | 85d |  |  | Out-of-House Narration | 320h |

Notes:
- 635: 3 Tracks: / 1 - Battle Drums / 2 - Dirge / 3 - Fanfare
- 636: 10 Original Scores: / 1 - Success / 2 - Failure / 3 - Grim / 4 - Marching / 5 - Stealthy / 6 - Battle / 7 - Journey / 8 - Tribal / 9 - Temple (chanting) / 10 - Panic
- 637: Track 3 - Grim (2 Re-Mixes) / Track 4 - Marching (2 Re-Mixes) / Track 5 - Stealthy (2 Re-Mixes) / Track 6 - Battle (3 Re-Mixes) / Track 7 - Journey (2 Re-Mixes) / Track 8 - Tribal (2 Re-Mixes) / Track 9 - Temple (2 Re-Mixes) / Track 10 - Panic (2 Re-Mixes)
- 639: A medly of the Myth 3 Music
- 641: About 83 new sounds in total
- 642: About 30 sounds all together
- 643: About 20 sounds all together
- 644: About 10 sounds
- 648: Narration for: / Each of the 25 level Intros (About 2:00 each) / Each of the 25 level Successes (About 0:30 each) / Each of the 25 level Failures (About 0:30 each) / Each of the 22 Cut Scenes (About 0:45 each)
- 649: We have 22 unique voices: / Tutorial Voiceabout 50 lines / Connachtabout 50 lines + Unit Voice / Damasabout 40 lines + Unit Voice / Myrdred about 40 lines + Unit Voice / Emperor Leitrimabout 40 lines / Ravannaabout 30 lines + Unit Voice / Mjarinabout 30 lines / Moagimabout 20 lines / Travalabout 20 lines + Unit Voice / Mazzarinabout 15 lines / Heron Guardabout 10 lines + Unit Voice / Llancarfan Soldierabout 5 lines + Unit Voice / Llancarfan Archerabout 5 lines + Unit Voice / Warlockabout 5 lines + Unit Voice / Avataraabout 5 lines + Unit Voice / Oghreabout 5 lines / Spider Cultistsabout 5 lines + Unit Voice / Gower Berserkabout 5 lines + Unit Voice / Twelve Dun BerserkUnit Voice / Dwarven DemolitionistUnit Voice / Dwarven Axe-WarriorUnit Voice / PeasantUnit Voice
